# 3GPP_Work Plan

Schedule from MS Project, 2000-01-03 to 2005-12-15, A marks actual dates.

## Calendars

- Standard: Mon-Fri 08:00-12:00, 13:00-17:00; Sat-Sun off.

## Resources

| Resource |
| --- |
| NP |
| N1 |
| N2 |
| N3 |
| N4 |
| N5 |
| TP |
| T1 |
| T2 |
| T3 |
| RP |
| R1 |
| R2 |
| R3 |
| R4 |
| SP |
| S1 |
| S2 |
| S3 |
| S4 |
| S5 |
| PCG |
| GP |
| No |
| CN4 |
| ? |
| WG G2 |
| G2 |
| G1 |
| G4 |
| G3 |
| All |
| Generic |
| MLST |
| G5 |
| S3, G2 |
| WG T2 |
| GP,G1 |
| G4,G5 |
| OMA |
| GP-G2 |
| Yes |

## Schedule

| ID | WBS | Task | Duration | Start | Finish | Complete | Remaining | Baseline start | Baseline finish | Baseline duration | Total slack | Constraint | Resources | Work | Actual work | Text6 | Text9 | Text1 | Text4 | Text5 | Text7 | Text8 | Text11 | Text3 | Text10 | Text2 | Text12 |
| --- | --- | --- | --- | --- | --- | --- | --- | --- | --- | --- | --- | --- | --- | --- | --- | --- | --- | --- | --- | --- | --- | --- | --- | --- | --- | --- | --- |
| 1 | 1 | VERSION 2004 July 8th | 1d | 2000-01-03 | 2000-01-03 |  |  | 2000-01-03 | 2000-01-03 | 1d | 1552d |  |  |  |  | Rel | 2044 |  |  |  |  |  |  |  |  |  |  |
| 2 | 2 | "CTRL + a" to display all the 3GPP fields | 1d | 2000-01-03 | 2000-01-03 |  |  | 2000-01-03 | 2000-01-03 | 1d | 1552d |  |  |  |  |  | 1462 |  |  |  |  |  |  |  |  |  |  |
| 3 | 3 | Content of Rel-6 and after. Not frozen. | 1d | 2000-01-03 | 2000-01-03 |  |  | 2000-01-03 | 2000-01-03 | 1d | 1552d |  |  |  |  | Rel | 2058 |  |  |  |  |  |  |  |  |  |  |
| 5 | 4 | Evolutions of the transport in the UTRAN | 218d | 2003-03-03 | 2003-12-31 |  |  | 2003-03-03 | 2003-12-31 | 218d | 510d | start no earlier than 2003-03-03 | RP | 1744h |  | NA | Feat | ETRAN | Francois Courau, Alcatel | francois.courau@alcatel.fr | TSG | MCC_RAN | Generic |  |  |  |  |
| 6 | 8 | **Improvements of Radio Interface** | 1196d | 2000-08-14 A | 2005-03-15 | 78% | 269.05d | 2000-08-14 | 2004-09-15 | 1068d | 197d |  | RP | 41168h | 30970.8h | Rel-6 |  | RInImp |  |  | TSG |  |  |  |  |  |  |
| 7 | 5.1 | Improvement of inter-frequency and inter-system measurement | 968d | 2001-01-01 A | 2004-09-15 | 50% | 484d | 2001-01-01 | 2004-09-15 | 968d | 325d | finish no earlier than 2004-09-15 | R1 | 7744h | 3872h | Rel-6 | BB | RInImp-IfIsM | Antti Toskala, Nokia | antti.toskala@nokia.com | TSG | MCC RAN | Active | TS25.212, 25.215, 25.331, 25.423, 25.433 | 1216 |  |  |
| 8 | 5.2 | Improving Receiver Performance Requirements for the FDD UE | 401d | 2002-03-08 A | 2003-09-19 A | 100% |  | 2002-03-08 | 2003-09-19 | 401d |  | start no earlier than 2002-03-08 | R4 | 3208h | 3208h | Rel-6 | BB | RInImp-UERecPerf | Shimon Moshavi, Intel | shimon.moshavi@INTEL.COM | TSG |  | Active | TS25.101 | 1216 |  |  |
| 9 | 8.2 | **Base station classification** | 603d | 2000-08-14 A | 2002-12-04 A | 100% |  | 2000-08-14 | 2002-12-04 | 603d |  |  | R4 | 9648h | 9648h | Rel-6 |  | RInImp-BSClass |  |  | TSG |  |  |  |  |  |  |
| 10 | 8.2.1 | FDD Base station classification | 603d | 2000-08-14 A | 2002-12-04 A | 100% |  | 2000-08-14 | 2002-12-04 | 603d |  | finish no earlier than 2002-12-04 | R4 | 4824h | 4824h | Rel-6 | 1476 | RInImp-BSClass-FDD | A. Toskala, Nokia |  | TSG |  |  | TS25.104, TS25.141 |  | BaAs |  |
| 11 | 5.4 | UMTS-850 | 266d | 2002-12-06 A | 2003-12-12 A | 100% |  | 2002-12-06 | 2003-12-12 | 266d |  | finish no earlier than 2003-12-15 | R4 | 2128h | 2128h | Rel-6 | BB | RInImp-UMTS850 | Don Zelmer, Cingular | don.zelmer@cingular.com | TSG | MCC_RAN | Active | TS25.101, 25.104, 25.133, 25.141, 25.307, 25.331, TR25.942 | 1216 |  |  |
| 12 | 5.5 | DS-CDMA introduction in the 800 MHz band | 196d | 2003-03-14 A | 2003-12-12 A | 100% |  | 2003-03-14 | 2003-12-12 | 196d |  | finish no earlier than 2003-12-15 | R4 | 1568h | 1568h | Rel-6 | BB | RInImp-UMTS800 | Takehiro Nakamura, NTT DoCoMo | takehiro@wsp.yrp.nttdocomo.co.jp | TSG | MCC_RAN | Active | TS25.101, 25.104, 25.133, 25.141, 25.307, 25.331 | 1216 |  |  |
| 13 | 5.6 | UMTS 1.7/2.1 GHz | 261d | 2003-03-14 A | 2004-03-12 A | 100% |  | 2003-03-14 | 2004-03-12 | 261d |  | finish no earlier than 2004-03-15 | R4 | 2088h | 2088h | Rel-6 | BB | RInImp-UMTS1721 | Jussi Numminen, Nokia | jussi.numminen@NOKIA.COM | TSG | MCC RAN | Active | TS25.101, 25.104, 25.133, 25.141, 25.307, 25.331 | 1216 |  |  |
| 14 | 5.7 | **Improved Receiver Performance Requirements for HSDPA** | 326d | 2003-12-15 A | 2005-03-15 | 40% | 195.6d | 2003-12-15 | 2004-09-14 | 197d | 197d |  | R4 | 5216h | 1043.2h | Rel-6 |  | RInImp-HSPerf | Jussi Numminen, Nokia | jussi.numminen@NOKIA.COM | TSG | MCC RAN |  |  |  |  |  |
| 15 | 5.7.1 | Performance Requirements of Receive Diversity for HSDPA | 326d | 2003-12-15 A | 2005-03-15 | 40% | 195.6d | 2003-12-15 | 2004-09-14 | 197d | 197d | finish no earlier than 2005-03-15 | R4 | 2608h | 1043.2h | Rel-6 |  | RInImp-HSPerf-RxDiv | Takehiro Nakamura (NTT DoCoMo) | takehiro@wsp.yrp.nttdocomo.co.jp | TSG | MCC RAN |  | TS25.101 |  |  |  |
| 16 | 6 | **RAN Feasibility Studies** | 1197d? | 2000-08-14 A | 2005-03-15 | 81% | 223.45d? | 2000-08-14 | 2005-03-15 | 1197d | 196d |  | RP | 43064h | 29683.2h | Rel-6 |  |  |  |  |  |  |  |  |  |  |  |
| 17 | 6.1 | FS of the improved access to UE measurement data for CRNC to support TDD RRM | 270d? | 2002-12-06 A | 2003-12-18 A | 100% |  | 2002-12-06 | 2003-12-18 | 270d? |  | finish no earlier than 2003-09-19 | R3 | 2160h | 2160h | Rel-6 |  | RANimp-RRMopt-FSUEMsD | Jim Miller, Interdigital | jim.miller@interdigital.com | TSG |  |  |  |  |  |  |
| 18 | 6.2 | FS on Radio link performance enhancements | 1067d | 2000-08-14 A | 2004-09-15 | 95% | 53.35d | 2000-08-14 | 2004-06-15 | 1002d | 326d | finish no earlier than 2004-09-15 | R1 | 8536h | 8109.2h | Rel-6 | SI | RInImp-Rlperf | Antti Toskala, Nokia Networks | antti.toskala@nokia.com | TSG | MCC_RAN | Active | TR25.899 | 1216 |  |  |
| 19 | 6.3 | FS on Improvement of inter-frequency and inter-system measurements for 1.28 Mcps TDD | 461d | 2001-12-14 A | 2003-09-19 A | 100% |  | 2001-12-14 | 2003-09-19 | 461d |  | start no earlier than 2001-12-14 | R1 | 3688h | 3688h | Rel-6 | SI | RInImp-IfIsMLCR | Li Xiao Qiang, SAMSUNG | xqli@samsung.co.kr | TSG |  | Active | TR25.888 | 1216 |  | 10 |
| 20 | 6.4 | FS for the analysis of OFDM for UTRAN enhancement | 526d | 2002-06-10 A | 2004-06-14 A | 100% |  | 2002-06-10 | 2004-06-14 | 526d |  | start no earlier than 2002-06-10 | R1 | 4208h | 4208h | Rel-6 | SI | RInImp-FSOFDM | Sarah Boumendil, Nortel | boumendi@nortelnetworks.com | TSG | MCC_RAN | Active | TR25.892 | 1216 |  | 11 |
| 21 | 6.5 | FS on Uplink Enhancements for Dedicated Transport Channels | 396d | 2002-09-06 A | 2004-03-12 A | 100% |  | 2002-09-06 | 2004-03-12 | 396d |  | finish no earlier than 2004-03-12 | R1 | 3168h | 3168h | Rel-6 | SI | RInImp-FSUpDTrCh | Karri Ranta-aho, Nokia | Karri.Ranta-aho@nokia.com | TSG | MCC_RAN | Active | TR25.896 | 1216 |  | 12 |
| 22 | 6.6 | FS on Analysis on Higher Chip Rates for UTRA TDD evolutions | 528d | 2002-09-06 A | 2004-09-15 | 90% | 52.8d | 2002-09-06 | 2004-06-14 | 462d | 326d | finish no earlier than 2004-09-15 | R1 | 4224h | 3801.6h | Rel-6 | SI | RInImp-FSVHCRTDD | Tim Wilkinson, IPWireless | mbeale@ipwireless.com | TSG | MCC_RAN | Active | TR25.895 | 1216 |  | 13 |
| 23 | 6.7 | FS on Low Output Powers for general purpose FDD BSs | 128d | 2003-06-13 A | 2004-03-12 A | 100% |  | 2003-06-13 | 2004-03-12 | 128d |  | finish no earlier than 2004-03-12 | R3 | 1024h | 1024h | Rel-6 | SI | RInImp-FSLoPw | Ana Burgos, Telefonica | burgos_a@tsm.es | TSG | MCC_RAN | Active | TR25.807 | 1216 |  | 14 |
| 24 | 6.8 | FS on Uplink enhancements for UTRA TDD | 398d | 2003-06-06 A | 2004-12-15 | 20% | 318.4d | 2003-06-06 | 2004-09-14 | 333d | 261d | finish no earlier than 2004-12-15 | R1 | 3184h | 636.8h | Rel-6 | SI | RInImp-FSUpEnhTDD | Marian Rudolf, Interdigital | Marian.Rudolf@InterDigital.com | TSG | MCC_RAN | Active | TR25.804 | 1216 |  | 15 |
| 25 | 8.8 | FS on UE antenna efficiency test methods performance requirements (2) | 131d | 2002-03-08 A | 2002-09-06 A | 100% |  | 2002-03-08 | 2002-09-06 | 131d |  | finish no earlier than 2002-09-06 | R4 | 1048h | 1048h | Rel-6 |  | RInImp-UEAnTM2 | Alf Ahlström, Allgon |  | TSG |  |  |  |  |  |  |
| 26 | 9.4 | FS on the evolution of the UTRAN architecture | 657d | 2002-09-09 A | 2005-03-15 | 35% | 427.05d | 2002-09-09 | 2005-03-15 | 657d | 196d | finish no earlier than 2005-03-15 | R3 | 5256h | 1839.6h | Rel-6 |  | RANimp-FSEvo | Woonhee Hwang, Nokia | Antti.Toskala@nokia.com | TSG | MCC_RAN |  |  |  |  |  |

Notes:
- 5: Generic feature
- 6: This is a generic feature without particular end date
- 25: The RInImp-UEAnTM FS was re-opened at TSG RAN#15 upon request from WG4
- 26: Work stopped until completion of MBMS in RAN3

| ID | WBS | Task | Duration | Start | Finish | Complete | Remaining | Baseline start | Baseline finish | Baseline duration | Total slack | Constraint | Resources | Work | Actual work | Text1 | Text4 | Text5 | Text6 | Text7 | Text8 | Text9 | Text10 | Text11 | Text12 | Text2 |
| --- | --- | --- | --- | --- | --- | --- | --- | --- | --- | --- | --- | --- | --- | --- | --- | --- | --- | --- | --- | --- | --- | --- | --- | --- | --- | --- |
| 27 | 8.5 | **Multiple Input Multiple Output antennas (MIMO)** | 719d? | 2003-03-14 A | 2005-12-15 | 10% | 647.04d? | 2003-03-14 | 2005-03-15 | 523d? | 0d |  | R1 | 23552h | 3880.8h | MIMO | Howard Huang, Lucent | hchuang@lucent.com | Rel-6 | TSG | MCC_RAN | 2468 |  |  |  |  |
| 28 | 7.1 | MIMO - Physical layer | 393d? | 2003-09-12 A | 2005-03-15 | 50% | 196.5d? | 2003-09-12 | 2005-03-15 | 393d? | 196d | finish no earlier than 2004-09-14 | R1 | 3144h | 1572h | MIMO-Phys | Howard Huang, Lucent | hchuang@lucent.com | Rel-6 | TSG | MCC RAN |  |  |  |  |  |
| 29 | 7.2 | MIMO - Layer 2,3 aspects | 589d? | 2003-09-12 | 2005-12-15 |  |  | 2003-09-12 | 2004-12-15 | 329d? | 0d | finish no earlier than 2005-12-15 | R2 | 4712h |  | MIMO-L23 | Howard Huang, Lucent | hchuang@lucent.com | Rel-6 | TSG | MCC RAN |  |  |  |  |  |
| 30 | 7.3 | MIMO - Iub/Iur Protocol Aspects | 719d? | 2003-03-14 | 2005-12-15 |  |  | 2003-03-14 | 2004-12-15 | 459d? | 0d | finish no earlier than 2005-12-15 | R3 | 5752h |  | MIMO-IurIub | Howard Huang, Lucent | hchuang@lucent.com | Rel-6 | TSG | MCC RAN |  |  |  |  |  |
| 31 | 7.4 | MIMO - RF Radio Transmission/Reception, System Performance Requirements and Conformance Testing | 524d? | 2003-12-12 A | 2005-12-15 | 5% | 497.8d? | 2003-12-12 | 2005-03-15 | 328d? | 0d | finish no earlier than 2005-12-15 | R4 | 4192h | 209.6h | MIMO-RF | Man Hung Ng, Lucent | ngm@lucent.com | Rel-6 | TSG | MCC RAN |  |  |  |  |  |
| 32 | 8 | **FDD Enhanced Uplink** | 327d | 2004-03-15 A | 2005-06-15 | 6% | 308.46d | 2004-03-15 | 2005-06-15 | 327d | 131d |  | RP | 11024h | 476.8h | EDCH | Joakim Bergström (Ericsson) |  |  | TSG | MCC RAN | Feat | 20003 | Active |  |  |
| 33 | 8.1 | FDD Enhanced Uplink - Stage 2 | 133d | 2004-03-15 A | 2004-09-15 | 30% | 93.1d | 2004-03-15 | 2004-03-15 | 1d | 325d | finish no earlier than 2004-09-15 | R2 | 1064h | 319.2h | EDCH-Stage2 |  |  |  | TSG |  |  |  |  |  |  |
| 34 | 8.2 | FDD Enhanced Uplink - Physical Layer | 197d | 2004-03-15 A | 2004-12-15 | 5% | 187.15d | 2004-03-15 | 2004-12-15 | 197d | 261d | finish no earlier than 2004-12-15 | R1 | 1576h | 78.8h | EDCH-Phys | Karri Ranta-aho (Nokia) |  |  | TSG | MCC RAN | BB | 20003 | Active | 26 |  |
| 35 | 8.3 | FDD Enhanced Uplink - Layer 2 and 3 Protocol Aspects | 197d | 2004-03-15 A | 2004-12-15 | 5% | 187.15d | 2004-03-15 | 2004-12-15 | 197d | 261d | finish no earlier than 2004-12-15 | R2 | 1576h | 78.8h | EDCH-L23 | Joakim Bergström (Ericsson) |  |  | TSG | MCC RAN | BB | 20003 | Active | 27 |  |
| 36 | 8.4 | FDD Enhanced Uplink - UTRAN Iub/Iur Protocol Aspects | 197d | 2004-03-15 | 2004-12-15 |  |  | 2004-03-15 | 2004-12-15 | 197d | 261d | finish no earlier than 2004-12-15 | R3 | 1576h |  | EDCH-IurIub | Saso Stojanovski (Nortel) |  |  | TSG | MCC RAN | BB | 20003 | Active | 28 |  |
| 37 | 8.5 | FDD Enhanced Uplink - RF Radio Transmission/ Reception, System Performance Requirements and Conformance Testing | 327d | 2004-03-15 | 2005-06-15 |  |  | 2004-03-15 | 2005-06-15 | 327d | 131d | finish no earlier than 2005-06-15 | R4 | 2616h |  | EDCH-RF | Thomas Unshelm (Ericsson) | thomas.unshelm@ERICSSON.COM |  | TSG | MCC RAN | BB | 20003 | Active | 29 |  |
| 38 | 9 | **RAN improvements** | 592d? | 2002-09-09 A | 2004-12-15 | 55% | 268.08d? | 2002-09-09 | 2004-12-15 | 592d? | 261d |  | RP | 27832h | 12761.2h | RANimp |  |  | Rel-6 | TSG | MCC_RAN |  |  |  |  |  |
| 39 | 9.2 | **RAB support enhancement** | 458d? | 2003-03-14 A | 2004-12-15 | 11% | 406.76d? | 2003-03-14 | 2004-12-15 | 458d? | 261d |  | R2 | 9384h | 852.8h | RANimp-RABSE | Juha Mikola, Nokia | juha.mikola@nokia.com | Rel-6 | TSG | MCC RAN | 624 |  |  |  | BaAS |
| 40 | 9.1.1 | Iu enhancements for IMS support in RAN | 320d? | 2003-03-14 A | 2004-06-04 | 25% | 240d? | 2003-03-14 | 2004-12-15 | 458d? | 399d | finish no earlier than 2004-06-04 | R3 | 2560h | 640h | RANimp-RABSE-IuEnhIMS | Phillipe Godin, Nortel | Philippe.Godin@nortelnetworks.com | Rel-6 | TSG | MCC RAN |  |  |  |  |  |
| 41 | 9.1.2 | Optimisation of downlink channelisation code utilisation | 198d | 2004-03-12 | 2004-12-15 |  |  | 2004-03-12 | 2004-12-15 | 198d | 261d | finish no earlier than 2004-12-15 | R1 | 1584h |  | RANimp-RABSE-CodeOptFDD | Sarah Boumendil (Nortel Networks) | boumendi@nortelnetworks.com |  | TSG | MCC RAN | WT | 624 | Active |  |  |
| 42 | 9.1.3 | Optimisation of channelisation code utilisation for TDD | 197d | 2004-03-15 | 2004-12-15 |  |  | 2004-03-15 | 2004-12-15 | 197d | 261d | finish no earlier than 2004-12-15 | R1 | 1576h |  | RANimp-RABSE-CodeOptTDD | Nicholas Anderson (IPWireless) |  |  | TSG | MCC RAN | WT | 624 | Active |  |  |
| 43 | 9.1 | Beamforming Enhancements | 66d | 2003-09-19 A | 2003-12-19 A | 100% |  | 2003-09-19 | 2003-12-19 | 66d |  | finish no earlier than 2004-03-12 | R1 | 528h | 528h | RANimp-BFE | Jussi Kähtävä, Nokia | jussi.kahtava@nokia.com | Rel-6 | TSG | MCC_RAN |  |  |  |  |  |
| 44 | 9.3 | **Rel6 RRM optimization for Iur and Iub** | 126d | 2003-09-19 A | 2004-03-12 A | 100% |  | 2003-09-19 | 2004-03-12 | 126d |  |  | R3 | 2016h | 2016h | RANimp-RRMopt | Gert-Jan van Lieshout, Ericsson | Gert-Jan.van.Lieshout@eln.ericsson.se | Rel-6 | TSG | MCC_RAN |  |  |  |  | BaAS |
| 45 | 9.3.1 | Improved access to User Equipment (UE) measurement data for Controlling Radio Network Controller (CRNC) to support Time Division Duplex (TDD) Radio Resource Management (RRM) | 126d | 2003-09-19 A | 2004-03-12 A | 100% |  | 2003-09-19 | 2004-03-12 | 126d |  | finish no earlier than 2004-03-15 | R3 | 1008h | 1008h | RANimp-RRMopt-UEMsD | Jim Miller, Interdigital | jim.miller@interdigital.com | Rel-6 | TSG | MCC RAN | WT | 23012 | Active | 22 |  |
| 46 | 9.4 | **Remote Control of Electrical Tilting Antennas** | 395d? | 2003-03-14 A | 2004-09-16 | 58% | 167.82d? | 2003-03-14 | 2004-09-16 | 395d? | 324d |  | R3 | 7472h | 3604.47h | RANimp-TiltAnt | Andreas Hauser, Vodafone | Andreas.Hauser@vodafone.com | Rel-6 | TSG | MCC_RAN |  |  |  |  |  |
| 47 | 9.4.1 | RAN aspects | 394d? | 2003-03-14 A | 2004-09-15 | 75% | 98.5d? | 2003-03-14 | 2004-09-15 | 394d? | 325d | finish no earlier than 2004-09-15 | R3 | 3152h | 2364h | RANimp-TiltAnt | Andreas Hauser, Vodafone | Andreas.Hauser@vodafone.com | Rel-6 | TSG | MCC_RAN |  |  |  |  |  |
| 48 | 9.4.2 | OAM&P impacts | 145d | 2004-02-27 A | 2004-09-16 | 10% | 130.5d | 2004-02-27 | 2004-09-16 | 145d | 324d | finish no earlier than 2004-09-16 | S5 | 1160h | 116h | RANimp-TiltAnt-OAM | John MUDGE, Vodafone | john.mudge@vodafone.co.uk | Rel-6 | WG | Adrian |  |  |  |  |  |
| 49 | 9.5 | Network Assisted Cell Change (NACC) from UTRAN to GERAN - network-side aspects | 462d? | 2002-09-09 A | 2004-06-15 A | 100% |  | 2002-09-09 | 2004-06-15 | 462d? |  | finish no earlier than 2004-06-15 | R3 | 3696h | 3696h | RANimp-NACC | Brendan McWilliams, Vodafone | Brendan.McWilliams@gb.vodafone.co.uk | Rel-6 | TSG | MCC_RAN |  |  |  |  |  |
| 50 | 10 | **PS domain and IMS impacts for supporting IMS Emergency calls** | 1255d? | 2000-08-14 A | 2005-06-03 | 36% | 799.31d? | 2000-08-14 | 2005-06-03 | 1255d? | 138d |  | S2 | 49760h | 15631.8h | EMC1 | Rainer Liebhart |  | Rel-7 | TSG |  |  |  |  |  |  |
| 51 | 10.1.1 | Service Requirements for IP-based emergency calls | 985d | 2000-09-18 A | 2004-06-25 A | 100% |  | 2000-09-18 | 2004-06-25 | 985d |  | finish no earlier than 2004-06-25 | S1 | 7880h | 7880h |  |  |  | Rel-7 |  |  | 1314 |  |  |  | CCaR |
| 52 | 10.2 | Stage 2 | 471d? | 2003-02-26 A | 2004-12-15 | 52% | 226.08d? | 2003-02-26 | 2004-12-15 | 471d? | 260d | finish no earlier than 2004-12-15 | S2 | 3768h | 1959.36h |  | Rainer Liebhart, Siemenws |  | Rel-7 | TSG |  |  |  |  |  |  |

Notes:
- 27: Text3: TR25.876,TR25.996
- 28: Text3: 25.211, 25.212, 25.213, 25.214, 25.215, 25.221, 25.222, 25.223, 25.224, 25.225
- 29: Text3: TR 25.876
- 33: Text3: TS 25.309
- 34: Text3: TS25.211, 25.212, 25.213, 25.214, 25.215
- 35: Text3: TS25.301, 25.302, 25.306, 25.321, 25.331
- 36: Text3: TS25.401, 25.420, 25.423, 25.430, 25.433
- 37: Text3: TS25.101, 25.104, 25.133, 25.141
- 38: Generic feature
- 39: This is a building block without particular end date / Text3: TR 25.862
- 40: Closed RAN#24 due to the lack of progress
- 43: Text3: TS24.215, 25.423, 25.425, 25.433, 25.435
- 45: Text3: TS25.423
- 47: Text3: TS25.460, 25.461, 25.462, 25.463
- 48: az: WID approved at SA5#37 (02/2004) / Text3: 32.804, 32.xyz
- 51: Text3: 22.976
- 52: Text3: 23.228, 23.060, 23.002

| ID | WBS | Task | Duration | Start | Finish | Complete | Remaining | Baseline start | Baseline finish | Baseline duration | Total slack | Constraint | Resources | Work | Actual work | Text2 | Text4 | Text5 | Text6 | Text9 | Text3 | Text1 | Text7 | Text8 |
| --- | --- | --- | --- | --- | --- | --- | --- | --- | --- | --- | --- | --- | --- | --- | --- | --- | --- | --- | --- | --- | --- | --- | --- | --- |
| 53 | 10.1 | **Emergency Call Enhancements for IP& PS Based Calls – stage 3** | 1255d | 2000-08-14 A | 2005-06-03 | 8% | 1156.47d | 2000-08-14 | 2005-06-03 | 1255d | 138d |  | N1 | 28272h | 2219.53h | CCaR | Mr Atle Monrad, Ericsson | Atle.Monrad@eto.ericsson.se | Rel-7 | 1653 |  |  |  |  |
| 54 | 10.1.2 | SIP emergency calls and packet emergency calls signalling flows | 1209d | 2000-10-17 A | 2005-06-03 | 16% | 1015.56d | 2000-10-17 | 2005-06-03 | 1209d | 138d | finish no earlier than 2005-06-03 | N1 | 9672h | 1547.52h | CCaR | Mr Atle Monrad, Ericsson | Atle.Monrad@eto.ericsson.se | Rel-7 | 1315 | TS 24.228 |  |  |  |
| 55 | 10.1.5 | Stage 3 for emergency calls and packet emergency calls in general | 1255d | 2000-08-14 | 2005-06-03 |  |  | 2000-08-14 | 2005-06-03 | 1255d | 138d | finish no earlier than 2005-06-03 | N1 | 10040h |  | CCaR | Mr Atle Monrad, Ericsson | Atle.Monrad@eto.ericsson.se | Rel-7 | 1646 | TS 24.229 |  |  |  |
| 56 | 12 | **Location Services enhancements 2** | 990d? | 2001-01-15 A | 2004-10-29 | 59% | 405.49d? | 2000-08-28 | 2004-10-29 | 1090d? | 293d |  | S2 | 88616h | 46893.2h |  |  |  | Rel-6 |  | 23.271 | LCS2 | TSG | Sang-Ui |
| 57 | 12.1 | **Improvement on Le interface** | 620d? | 2002-06-17 A | 2004-10-29 | 49% | 315.07d? | 2002-06-17 | 2004-10-29 | 620d? | 293d |  | S2 | 10344h | 5087.47h |  |  |  | Rel-6 |  |  |  | TSG |  |
| 58 | 11.1.1 | Stage 2 | 331d? | 2002-06-17 A | 2003-09-22 A | 100% |  | 2002-06-17 | 2003-09-22 | 331d? |  | start no earlier than 2002-06-17 | S2 | 2648h | 2648h |  |  |  | Rel-6 |  |  |  |  |  |
| 59 | 11.1.2 | Stage 3 - impacts MLP (Mobile Location Protocol) | 342d? | 2003-07-10 | 2004-10-29 |  |  | 2003-07-10 | 2004-10-29 | 342d? | 293d | finish no earlier than 2004-10-29 | OMA | 2736h |  |  |  | OMA-LIAISON@mail.openmobilealliance.org | Rel-6 |  |  |  |  |  |
| 60 | 12.2 | **Enhanced support for anonymity and user privacy** | 605d? | 2002-07-08 A | 2004-10-29 | 43% | 346.58d? | 2002-07-08 | 2004-10-29 | 605d? | 293d |  | S2 | 9616h | 4072.03h |  |  |  | Rel-6 |  |  |  | TSG |  |
| 61 | 11.2.1 | Stage 2 | 255d? | 2002-07-08 A | 2003-06-27 A | 100% |  | 2002-07-08 | 2003-06-27 | 255d? |  | finish no earlier than 2003-06-27 | S2 | 2040h | 2040h |  |  |  | Rel-6 |  |  |  |  |  |
| 62 | 11.2.2 | Stage 3 - impacts MLP and RLP | 342d? | 2003-07-10 | 2004-10-29 |  |  | 2003-07-10 | 2004-10-29 | 342d? | 293d | finish no earlier than 2004-10-29 | OMA | 2736h |  |  |  | OMA-LIAISON@mail.openmobilealliance.org | Rel-6 |  |  |  |  |  |
| 63 | 12.3 | **Enhanced inter-GMLC interface** | 615d? | 2002-06-24 A | 2004-10-29 | 56% | 272.21d? | 2002-06-24 | 2004-10-29 | 615d? | 293d |  | S2 | 11960h | 6666.34h |  |  |  | Rel-6 |  |  |  | TSG |  |
| 64 | 11.3.1 | Stage 2 | 315d? | 2002-06-24 A | 2003-09-05 A | 100% |  | 2002-06-24 | 2003-09-05 | 315d? |  | finish no earlier than 2003-09-05 | S2 | 2520h | 2520h |  |  |  | Rel-6 |  |  |  |  |  |
| 65 | 11.3.2 | Stage 3 - definition of RLP and PCP | 565d? | 2002-09-02 A | 2004-10-29 | 31% | 389.5d? | 2002-09-02 | 2004-10-29 | 565d? | 293d | finish no earlier than 2004-10-29 | OMA | 4520h | 1404h |  |  | OMA-LIAISON@mail.openmobilealliance.org | Rel-6 |  |  |  |  |  |
| 66 | 12.4 | **Location Services support for IMS public identities** | 565d? | 2002-09-02 A | 2004-10-29 | 51% | 274.85d? | 2002-09-02 | 2004-10-29 | 565d? | 293d |  | S2 | 9960h | 4833.75h |  |  |  | Rel-6 |  |  |  | TSG |  |
| 67 | 11.4.1 | Stage 2 | 240d? | 2003-02-24 A | 2004-01-23 A | 100% |  | 2003-02-24 | 2004-01-23 | 240d? |  | finish no earlier than 2004-01-23 | S2 | 1920h | 1920h |  |  |  | Rel-6 |  |  |  |  |  |
| 68 | 11.4.2 | Stage 3 - impacts MLP, RLP and PCP | 565d? | 2002-09-02 A | 2004-10-29 | 31% | 391.6d? | 2002-09-02 | 2004-10-29 | 565d? | 293d | finish no earlier than 2004-10-29 | OMA | 4520h | 1387.2h |  |  | OMA-LIAISON@mail.openmobilealliance.org | Rel-6 |  |  |  |  |  |
| 69 | 12.5 | **New area event for location service triggering reports** | 630d? | 2002-06-03 A | 2004-10-29 | 51% | 309.51d? | 2002-06-03 | 2004-10-29 | 630d? | 293d |  | S2 | 11872h | 5707.55h |  |  |  | Rel-6 |  |  |  | TSG |  |
| 70 | 11.5.1 | Stage 2 | 280d? | 2002-06-03 A | 2003-06-27 A | 100% |  | 2002-06-03 | 2003-06-27 | 280d? |  | finish no earlier than 2003-06-27 | S2 | 2240h | 2240h |  |  |  | Rel-6 |  |  |  |  |  |
| 71 | 11.5.2 | Stage 3 for UE-CN signalling | 234d? | 2003-10-09 A | 2004-08-31 | 66% | 79.56d? | 2003-10-09 | 2004-08-31 | 234d? | 336d | finish no earlier than 2004-08-31 | N4 | 1872h | 1235.52h |  |  |  | Rel-6 |  |  |  |  |  |
| 72 | 11.5.3 | Stage 3 - impacts MLP, RLP and PCP | 340d? | 2003-07-14 | 2004-10-29 |  |  | 2003-07-14 | 2004-10-29 | 340d? | 293d | finish no earlier than 2004-10-29 | OMA | 2720h |  |  |  | OMA-LIAISON@mail.openmobilealliance.org | Rel-6 |  |  |  |  |  |
| 73 | 12.6 | **FS on applicability of GALILEO for LCS** | 518d? | 2002-07-08 A | 2004-06-30 | 54% | 236.22d? | 2002-07-08 | 2004-06-30 | 518d? | 380d |  | S2 | 9248h | 3776.48h |  |  |  | Rel-6 |  |  |  |  |  |
| 74 | 11.6.1 | TR on Stage 2 (No contributions received, No feedback from other groups since May) | 518d? | 2002-07-08 A | 2004-06-30 | 67% | 170.94d? | 2002-07-08 | 2004-06-30 | 518d? | 380d | finish no earlier than 2004-06-30 | S2 | 4144h | 2776.48h |  |  |  | Rel-6 |  |  |  |  |  |
| 75 | 11.6.2 | GERAN review of the TR | 120d? | 2003-08-25 | 2004-02-06 |  |  | 2003-08-25 | 2004-02-06 | 120d? | 483d | finish no earlier than 2004-02-06 | GP | 960h |  |  |  |  | Rel-6 |  |  |  |  |  |
| 76 | 12.7 | **UE positioning** | 958d? | 2001-01-15 A | 2004-09-15 | 85% | 141.79d? | 2000-08-28 | 2004-09-15 | 1058d? | 325d |  | RP | 18496h | 12545.8h |  |  |  | Rel-6 |  |  | LCS2-UEpos | TSG | MCC_RAN |
| 77 | 12.8 | Open SMLC-SRNC Interface within the UTRAN to support UTRAN Rel4 positioning methods | 700d? | 2001-01-15 A | 2003-09-19 A | 100% |  | 2001-01-15 | 2003-09-19 | 700d? |  | finish no earlier than 2003-09-19 | R2 | 5600h | 5600h |  | Meik Kottkamp, Siemens | Meik.Kottkamp@siemens.com | Rel-6 | 2475 | TS25.305, 25.401, 25.450, 25.452, 25.453 | LCS-Rel4Pos | TSG |  |
| 78 | 11.7.2 | A-GPS minimum performance specification | 334d? | 2003-06-06 A | 2004-09-15 | 40% | 200.4d? | 2003-06-06 | 2004-09-15 | 334d? | 325d | finish no earlier than 2004-09-15 | R4 | 2672h | 1068.8h |  | Donglin Shen, AT&T Wireless Services | donglin.shen@attws.com | Rel-6 |  | TS25.171 | LCS-UEPos-AGPSPerf | TSG | MCC_RAN |
| 79 | 12.7.2 | FS on Enhancements to OTDOA Positioning using advanced blanking methods | 320d | 2002-07-01 A | 2003-09-19 A | 100% |  | 2002-07-01 | 2003-09-19 | 320d |  | finish no earlier than 2003-09-19 | R2 | 2560h | 2560h |  | David Bartlett, Cambridge Positioning Systems | david.bartlett@cursor-system.com | Rel-6 |  |  | LCS2-UEpos-FSBlank | TSG |  |

Notes:
- 59: Updated according to SP-040232
- 62: Updated according to SP-040232
- 65: Updated according to SP-040232
- 68: Updated according to SP-040232
- 71: 31/10/2003 work has started. Current stage 3 fullfills the requirements of stage 2. ...
- 72: Updated according to SP-040232

| ID | WBS | Task | Duration | Start | Finish | Complete | Remaining | Baseline start | Baseline finish | Baseline duration | Total slack | Constraint | Resources | Work | Actual work | Text1 | Text4 | Text5 | Text6 | Text7 | Text8 | Text9 | Text2 |
| --- | --- | --- | --- | --- | --- | --- | --- | --- | --- | --- | --- | --- | --- | --- | --- | --- | --- | --- | --- | --- | --- | --- | --- |
| 80 | 14 | **Security enhancements** | 903d? | 2001-01-03 A | 2004-06-18 | 38% | 559.78d? | 2001-01-03 | 2004-06-18 | 903d? | 388d |  | S3 | 26984h | 9747.78h | SEC1 | Peter Howard, Vodafone | Peter.Howard@vodafone.com | Rel-6 | TSG | Maurice |  |  |
| 81 | 14.1 | **Enhanced HE control of security (including positive authentication reporting)** | 712d | 2001-01-03 A | 2003-09-25 | 23% | 545d | 2001-01-03 | 2003-09-25 | 712d | 579d |  | S3 | 14064h | 4008h |  | Peter Howard, Vodafone | Peter.Howard@vodafone.com | Rel-6 |  |  | 2026 |  |
| 82 | 14.1.1 | Stage 2 | 378d | 2001-01-03 | 2002-06-14 |  |  | 2001-01-03 | 2002-06-14 | 378d | 913d | finish no earlier than 2002-06-14 | S3 | 3024h |  |  |  |  | Rel-6 |  |  | 2027 |  |
| 83 | 14.1.3 | **Network domain security** | 334d | 2002-06-17 A | 2003-09-25 | 50% | 167d | 2002-06-17 | 2003-09-25 | 334d | 579d |  | S3 | 5344h | 2672h | SEC1-NDS | Geir M. Køien, Telenor | Geir-myrdahl.koien@telenor.com | Rel-6 | TSG |  |  | Sec |
| 84 | 14.1.3.1 | IP network layer security (NDS/IP) | 334d | 2002-06-17 A | 2003-09-25 | 50% | 167d | 2002-06-17 | 2003-09-25 | 334d | 579d | finish no earlier than 2003-09-25 | S3 | 2672h | 1336h | SEC1-NDS-IP |  |  | Rel-6 | WG |  |  |  |
| 85 | 12.2 | Network Domain Security; Authentication Framework (NDS/AF) | 521d? | 2002-02-15 A | 2004-02-13 | 70% | 156.3d? | 2002-02-15 | 2004-02-13 | 521d? | 478d | finish no earlier than 2004-02-13 | S3 | 4168h | 2917.6h | SEC1-NDS-AF | Tommi Viitanen, Nokia | tommi.viitanen@nokia.com | Rel-6 | TSG |  |  |  |
| 86 | 12.3 | Key Management of group keys for Voice Group Call Services | 191d | 2003-09-26 A | 2004-06-18 | 5% | 181.45d | 2003-09-26 | 2004-06-18 | 191d | 388d | finish no earlier than 2004-06-18 | S3 | 1528h | 76.4h | SECGKYV | Benno Tietz, Vodafone D2 | benno.tietz@vodafone.com | Rel-6 | TSG | Maurice |  |  |
| 87 | 16 | **IMS Phase 2** | 1112d? | 2000-08-28 A | 2004-11-30 | 65% | 394.61d? | 2000-08-28 | 2004-11-30 | 1112d? | 271d |  | S1 | 120888h | 74750.6h | IMS2 |  |  | Rel-6 | TSG | Sang-Ui |  |  |
| 88 | 13.1 | Enhancements to the Cx and Sh interfaces | 323d? | 2003-06-06 A | 2004-08-31 | 60% | 129.2d? | 2003-06-06 | 2004-08-31 | 323d? | 336d | finish no earlier than 2004-08-31 | N4 | 2584h | 1550.4h | IMS2-CCR |  |  | Rel-6 | WG |  |  |  |
| 89 | 16.12 | **IMS Group Management** | 650d? | 2002-03-14 A | 2004-09-08 | 72% | 183.29d? | 2002-03-14 | 2004-09-08 | 650d? | 330d |  | S1 | 11640h | 8357.66h | IMSGM | Juha Kalliokulju (Nokia) | juha.kalliokulju@nokia.com | Rel-6 | TSG |  |  |  |
| 90 | 16.12.1 | Stage 1 - TS on IMS group management | 193d | 2002-03-14 A | 2002-12-09 A | 100% |  | 2002-03-14 | 2002-12-09 | 193d |  | finish no earlier than 2002-12-09 | S1 | 1544h | 1544h |  | Juha Kalliokulju (Nokia) | juha.kalliokulju@nokia.com | Rel-6 | TSG |  |  |  |
| 91 | 13.2.2 | Stage 2 | 158d? | 2003-05-26 A | 2003-12-31 A | 100% |  | 2003-05-26 | 2003-12-31 | 158d? |  | finish no earlier than 2003-12-31 | S2 | 1264h | 1264h |  |  |  | Rel-6 |  |  |  |  |
| 92 | 13.2.3 | Stage 3 for IMS Group management (e.g. chat) | 454d? | 2002-12-13 A | 2004-09-08 | 50% | 227d? | 2002-12-13 | 2004-09-08 | 454d? | 330d | finish no earlier than 2004-09-08 | N1 | 3632h | 1816h |  | Keith Drage, Lucent | drage@lucent.com |  |  |  |  |  |
| 93 | 13.3 | **IMS Conferencing** | 483d? | 2002-11-04 A | 2004-09-08 | 88% | 57.93d? | 2002-11-04 | 2004-09-08 | 483d? | 330d |  | N1 | 9920h | 8730.12h |  |  |  | Rel-6 |  |  |  |  |
| 94 | 13.3.1 | Stage 2 | 303d? | 2002-11-04 A | 2003-12-31 A | 100% |  | 2002-11-04 | 2003-12-31 | 303d? |  | finish no earlier than 2003-12-31 | S2 | 2424h | 2424h |  |  |  | Rel-6 |  |  |  |  |
| 95 | 13.3.2 | Stage 3 | 454d? | 2002-12-13 A | 2004-09-08 | 80% | 90.8d? | 2002-12-13 | 2004-09-08 | 454d? | 330d | finish no earlier than 2004-09-08 | N1 | 3632h | 2905.6h |  | Keith Drage, Lucent | drage@lucent.com |  |  |  |  |  |
| 96 | 16.11 | **IMS Messaging** | 650d? | 2002-03-14 A | 2004-09-08 | 71% | 186.92d? | 2002-03-14 | 2004-09-08 | 650d? | 330d |  | S1 | 17520h | 12481.8h | IMSM | Juha Kalliokulju (Nokia) | juha.kalliokulju@nokia.com | Rel-6 | TSG |  |  |  |
| 97 | 16.11.1 | TR on support of messaging in the IMS | 193d | 2002-03-14 A | 2002-12-09 A | 100% |  | 2002-03-14 | 2002-12-09 | 193d |  | finish no earlier than 2002-12-09 | S1 | 1544h | 1544h | IMSM-TR | Juha Kalliokulju (Nokia) | juha.kalliokulju@nokia.com | Rel-6 | TSG |  |  |  |
| 98 | 13.4.2 | Stage 1 22.340 | 23d? | 2002-11-11 A | 2002-12-11 A | 100% |  | 2002-11-11 | 2002-12-11 | 23d? |  | finish no earlier than 2002-12-11 | S1 | 184h | 184h | IMSM-TS | Juha Kalliokulju (Nokia) | juha.kalliokulju@nokia.com | Rel-6 | TSG |  |  |  |
| 99 | 13.4.3 | CRs to 22.140 & 22.228 | 263d? | 2002-03-14 A | 2003-03-17 A | 100% |  | 2002-03-14 | 2003-03-17 | 263d? |  | finish no earlier than 2003-03-17 | S1 | 2104h | 2104h | IMSM-CR | Juha Kalliokulju (Nokia) | juha.kalliokulju@nokia.com | Rel-6 | TSG |  |  |  |
| 100 | 16.11.3 | Stage 2 | 477d | 2002-11-04 A | 2004-08-31 | 82% | 85.86d | 2002-11-04 | 2004-08-31 | 477d | 336d | finish no earlier than 2004-08-31 | S2 | 3816h | 3129.12h |  |  |  | Rel-6 |  |  |  |  |
| 101 | 13.4.5 | Stage 3 for IMS Messaging | 454d? | 2002-12-13 A | 2004-09-08 | 50% | 227d? | 2002-12-13 | 2004-09-08 | 454d? | 330d | finish no earlier than 2004-09-08 | N1 | 3632h | 1816h |  | Keith Drage, Lucent | drage@lucent.com |  |  |  |  |  |
| 102 | 13.4.6 | SIP/SIMPLE Instant messaging | 130d? | 2004-01-01 | 2004-06-30 |  |  | 2004-01-01 | 2004-06-30 | 130d? | 380d | finish no earlier than 2004-06-30 | OMA | 1040h |  |  |  | OMA-LIAISON@mail.openmobilealliance.org | Rel-6 | n/a |  |  |  |
| 103 | 16.7 | **IMS Local services** | 895d? | 2001-01-01 A | 2004-06-04 | 46% | 485.89d? | 2001-01-01 | 2004-06-04 | 895d? | 398d |  | S2 | 12848h | 5192.02h |  |  |  | Rel-6 |  |  |  |  |
| 104 | 16.7.1 | Stage 2 | 325d | 2001-01-01 A | 2002-03-29 A | 100% |  | 2001-01-01 | 2002-03-29 | 325d |  | start no earlier than 2001-01-01 | S2 | 2600h | 2600h |  |  |  | Rel-6 |  |  |  |  |
| 105 | 13.5.2 | Stage 3 for IMS Local services | 386d? | 2002-12-13 | 2004-06-04 |  |  | 2002-12-13 | 2004-06-04 | 386d? | 398d | finish no earlier than 2004-06-04 | N1 | 3088h |  |  | Keith Drage, Lucent | drage@lucent.com |  |  |  |  |  |

Notes:
- 80: Added BB UE authentication and rapporteur added.
- 81: Added by P-000575 without any dates. 18/10/00: Change of WI title, added hyperlink rapporteur new end date 03/01. New end date and correct Release to be decided S3#18
- 82: New end date and correct Release to be decided S3#18
- 83: WID approved for Rel-6 at SA#17
- 84: Should be complete after SA3#27 / Text3: TS 33.210
- 85: WID approved SA#19. Work started after FS approved SA#18
- 86: Approved TSG#21 / Text3: 42.068, 43.068, 44.068, 42.069, 43.069, 44.069, 31.102, 24.008, 48.008, 42.009, 43.020
- 87: Not yet available: verbally approved at SA15, actual WID to be provided at SA16 by Lucent / Text3: 23.228
- 88: 29/05/2003 CN4: New WID presented for approval at CN#20............
- 98: Text3: 22.340
- 99: Text3: 22.140,22.228
- 102: Updated according to SP-040232
- 103: Text3: 23.228

| ID | WBS | Task | Duration | Start | Finish | Complete | Remaining | Baseline start | Baseline finish | Baseline duration | Total slack | Constraint | Resources | Work | Actual work | Text6 | Text4 | Text5 | Text1 | Text2 | Text3 | Text7 | Text9 | Text8 |
| --- | --- | --- | --- | --- | --- | --- | --- | --- | --- | --- | --- | --- | --- | --- | --- | --- | --- | --- | --- | --- | --- | --- | --- | --- |
| 106 | 13.6 | **Additional SIP Capabilities support not covered by Rel-5** | 478d? | 2002-11-11 A | 2004-09-08 | 77% | 110.02d? | 2002-11-11 | 2004-09-08 | 478d? | 330d |  | N1 | 10136h | 7803.05h | Rel-6 |  |  |  |  |  |  |  |  |
| 107 | 13.6.1 | Stage 2 for add SIP cap (e.g. forking) | 335d? | 2002-11-11 A | 2004-02-20 A | 100% |  | 2002-11-11 | 2004-02-20 | 335d? |  | finish no earlier than 2004-02-20 | S2 | 2680h | 2680h | Rel-6 |  |  |  |  |  |  |  |  |
| 108 | 13.6.2 | Stage 3 for Additional SIP Capabilities | 454d? | 2002-12-13 A | 2004-09-08 | 60% | 181.6d? | 2002-12-13 | 2004-09-08 | 454d? | 330d | finish no earlier than 2004-09-08 | N1 | 3632h | 2179.2h |  | Keith Drage, Lucent | drage@lucent.com |  |  |  |  |  |  |
| 109 | 13.7 | Review additional SIP Capabilities against IMS | 326d? | 2002-12-13 A | 2004-03-12 | 35% | 211.9d? | 2002-12-13 | 2004-03-12 | 326d? | 458d | finish no earlier than 2004-03-12 | N1 | 2608h | 912.8h |  | Keith Drage, Lucent | drage@lucent.com |  |  |  |  |  |  |
| 110 | 16.5 | **Interworking between IMS and IP networks** | 1055d? | 2000-08-28 A | 2004-09-10 | 60% | 420.73d? | 2000-08-28 | 2004-09-10 | 1055d? | 328d |  | N3 | 30704h | 15505.2h | Rel-6 | Nigel Holland, BT | nigel.holland@bt.com | IMS-CCR-IWIP | BaAS | 23.821, 29.061, 29.162 | TSG | 2048 |  |
| 111 | 16.5.1 | Interworking for 3GPP_SIP and IETF_SIP | 730d | 2000-08-28 A | 2003-06-13 A | 100% |  | 2000-08-28 | 2003-06-13 | 730d |  | finish no earlier than 2003-06-13 | N3 | 5840h | 5840h | Rel-6 | Thomas Belling, Siemens |  |  |  | New TR 29.962 |  |  |  |
| 112 | 16.5.2 | Interworking for IPv6 to IPv4 | 1055d | 2000-08-28 A | 2004-09-10 | 16% | 886.2d | 2000-08-28 | 2004-09-10 | 1055d | 328d | finish no earlier than 2004-09-10 | N3 | 8440h | 1350.4h | Rel-6 |  |  |  |  | 29.163 |  |  |  |
| 113 | 13.8.3 | Interworking for IPv6 to IPv4 (SIP / SDP aspects) | 87d? | 2004-05-11 | 2004-09-08 |  |  | 2004-05-11 | 2004-09-08 | 87d? | 330d | finish no earlier than 2004-09-08 | N1 | 696h |  | Rel-6 |  |  |  |  |  |  |  |  |
| 114 | 16.8.1 | stage 3 of interworking with non-IMS IP networks | 911d | 2001-03-14 A | 2004-09-08 | 85% | 136.65d | 2001-03-14 | 2004-09-08 | 911d | 330d | finish no earlier than 2004-09-08 | N1 | 7288h | 6194.8h | Rel-6 |  |  |  |  |  |  |  |  |
| 115 | 16.6.1 | Interworking between IMS and CS networks | 929d? | 2000-08-28 A | 2004-03-18 A | 100% |  | 2000-08-28 | 2004-03-18 | 929d? |  | finish no earlier than 2004-03-18 | N3 | 7432h | 7432h | Rel-6 | Brendan Mc Williams, Vodafone | brendan.mcwilliams@vf.vodafone.co.uk | IMS-CCR-IWCS | CCaR | 29.163, 29.061, 24.228, and new CN4 specification | TSG |  |  |
| 116 | 16.10 | Mn interface (IM-MGW to MGCF) enhancements (CN4 Part) | 418d | 2001-08-07 A | 2004-09-01 | 70% | 125.4d | 2001-08-07 | 2004-09-01 | 418d | 335d | finish no earlier than 2004-09-01 | N4 | 3344h | 2340.8h | Rel-6 |  |  | IMS-CCR-Mn |  |  |  |  |  |
| 117 | 13.11 | Mp (MRFC - MRFP) interface (CN4 Part) | 513d | 2002-12-13 | 2004-11-30 |  |  | 2002-12-13 | 2004-11-30 | 513d | 271d | finish no earlier than 2004-11-30 | N4 | 4104h |  | Rel-6 |  |  | IMS-CCR-Mp |  |  |  |  |  |
| 118 | 13.12 | Study of subscriber and operators relationship in IMS and related ISIM requirements for Rel 6” | 20d? | 2002-11-15 A | 2002-12-12 A | 100% |  | 2002-11-15 | 2002-12-12 | 20d? |  | finish no earlier than 2002-12-12 | S1 | 160h | 160h | Rel-6 | Juha Kalliokulju (Nokia) | juha.kalliokulju@nokia.com |  |  |  |  |  |  |
| 119 | 13.13 | Lawful Interception in the 3GPP Rel-6 architecture | 269d? | 2002-12-09 A | 2003-12-18 | 10% | 242.1d? | 2002-12-09 | 2003-12-18 | 269d? | 519d | finish no earlier than 2003-12-18 | S3 | 2152h | 215.2h | Rel-6 | Berthold Wilhelm | Berthold.Wilhelm@REGTP.DE | SEC1-LI |  | 33.106, 33.107, 33.108 | TSG |  |  |
| 120 | 13.14 | IMS Subscription and access scenarios | 130d? | 2002-12-16 A | 2003-06-13 A | 100% |  | 2002-12-16 | 2003-06-13 | 130d? |  | start no earlier than 2002-12-16 | S1 | 1040h | 1040h | Rel-6 |  |  |  |  | 22.800 |  |  |  |
| 121 | 14 | **3GPP Enablers for services like Push to Talk over Cellular (PoC)** | 344d? | 2003-09-08 A | 2004-12-30 | 29% | 243.3d? | 2003-09-08 | 2004-12-30 | 344d? | 249d |  | S2 | 7416h | 2170.87h | R6/R7? | Shabnam Sultana, Ericsson |  | PoC |  | 23.979 | TSG |  |  |
| 122 | 14.1 | Feasibility Study | 322d? | 2003-09-08 A | 2004-11-30 | 53% | 151.34d? | 2003-09-08 | 2004-11-30 | 322d? | 271d | finish no earlier than 2004-11-30 | S2 | 2576h | 1365.28h | R6/R7? | Shabnam Sultana, Ericsson |  | PoC |  | 23.979 |  |  |  |
| 123 | 14.2 | Dependencies on OMA PoC | 261d? | 2004-01-01 | 2004-12-30 |  |  | 2004-01-01 | 2004-12-30 | 261d? | 249d | finish no earlier than 2004-12-30 | OMA | 2088h |  | R6/R7? |  | OMA-LIAISON@mail.openmobilealliance.org | PoC |  |  | n/a |  |  |
| 124 | 15 | Interworking aspects and migration scenarios for IPv4 based IMS Implementations (Study) | 210d? | 2003-09-08 A | 2004-06-25 A | 100% |  | 2003-09-08 | 2004-06-25 | 210d? |  | finish no earlier than 2004-06-25 | S2 | 1680h | 1680h | Rel-6 | Alexander Milinski, Siemens |  | IPv4IMS |  | 23.881 |  |  |  |
| 125 | 16.3 | **Interoperability and Commonality between IMS using different "IP-connectivity Networks"** | 325d? | 2002-09-16 A | 2003-12-12 A | 100% |  | 2002-09-16 | 2003-12-12 | 325d? |  |  | S2 | 9176h | 9176h | Rel-6 |  |  | IMSCOOP |  | 23.864 | TSG |  | Sang-Ui |
| 126 | 16.3.1 | Stage 2 for Interoperability (no contributions assumed that no more will be done in 3GPP hence work may need to be done in pp2) | 272d | 2002-09-16 A | 2003-09-30 A | 100% |  | 2002-09-16 | 2003-09-30 | 272d |  | finish no earlier than 2003-09-30 | S2 | 2176h | 2176h | Rel-6 | Balazs Beternyi, Nokia |  |  |  | 23.864 |  |  |  |
| 127 | 16.2 | Stage 2 for commonality | 265d? | 2002-09-16 A | 2003-09-19 A | 100% |  | 2002-09-16 | 2003-09-19 | 265d? |  | start no earlier than 2002-09-16 | S2 | 2120h | 2120h | Rel-6 | Balazs Beternyi, Nokia |  |  |  | 23.864 |  |  |  |
| 128 | 16.3.2 | Stage 3 | 305d | 2002-10-14 A | 2003-12-12 A | 100% |  | 2002-10-14 | 2003-12-12 | 305d |  | finish no earlier than 2003-12-12 | N1 | 2440h | 2440h | Rel-6 | Keith Drage, Lucent | drage@lucent.com |  |  |  |  |  |  |
| 129 | 17 | **Support of Push Services** | 823d | 2001-01-03 A | 2004-02-27 | 99% | 0d | 2001-01-03 | 2004-02-27 | 823d | 0d |  | S1 | 11390.6h | 5744h | Rel-6 | Yoshinori Kitada, NTT Comware |  | PUSH | CCaR | 23.976 | TSG | 1365 | Sang-Ui |
| 130 | 17.1 | Stage 1 | 378d | 2001-01-03 A | 2002-06-14 A | 100% |  | 2001-01-03 | 2002-06-14 | 378d |  | finish no earlier than 2002-06-14 | S1 | 3024h | 3024h | Rel-6 |  |  |  |  |  |  |  |  |
| 131 | 17.3 | TR 23.976 on Push Architecture | 340d | 2002-11-11 A | 2004-02-27 A | 100% |  | 2002-11-11 | 2004-02-27 | 340d |  | finish no earlier than 2004-02-27 | S2 | 2720h | 2720h | Rel-6 | Nick Alfano, RIM |  |  |  | 23.976 |  |  |  |

Notes:
- 110: [DAB 14.02.02] - end date pushed back to March 2003
- 111: [DAB - 20.08.03] - CN Part of TR Complete @ CN#20
- 112: [DAB - 25.05.04] - Awaiting Stage 2
- 115: [DAB - 25.05.04] - CN3 consider this work to be complete
- 116: [CN4] 17th May 2002, CN4; Will be handled in Rel-6.........
- 117: 27/11/2002 KK: WID approved at CN#18 (NP-020601)......
- 123: Updated according to SP-040232
- 129: AS: Changed from FS to actual support of Push

| ID | WBS | Task | Duration | Start | Finish | Complete | Remaining | Baseline start | Baseline finish | Baseline duration | Total slack | Constraint | Resources | Work | Actual work | Text1 | Text2 | Text4 | Text5 | Text6 | Text7 | Text8 | Text3 | Text9 |
| --- | --- | --- | --- | --- | --- | --- | --- | --- | --- | --- | --- | --- | --- | --- | --- | --- | --- | --- | --- | --- | --- | --- | --- | --- |
| 132 | 18 | **Multimedia Messaging (MMS) enhancements** | 556d? | 2002-08-15 A | 2004-09-30 | 62% | 212.14d? | 2002-08-15 | 2004-09-16 | 546d? | 314d |  | T2 | 22742.8h | 14938.3h | MMS6 | Mes | Josef Laumen, Siemens | Josef.Laumen@SAL.SIEMENS.DE | Rel-6 | TSG | Friedhelm |  |  |
| 133 | 18.1 | **Definition of service requirements** | 286d? | 2002-11-15 A | 2003-12-19 A | 100% |  | 2002-11-15 | 2003-12-19 | 286d? |  |  | S1 | 4576h | 4576h | MMS6-SR |  |  |  | Rel-6 |  |  | 22.140 |  |
| 134 | 18.1.1 | Definition of service requirements charging | 286d? | 2002-11-15 A | 2003-12-19 A | 100% |  | 2002-11-15 | 2003-12-19 | 286d? |  | finish no earlier than 2003-12-20 | S1 | 2288h | 2288h |  |  | Josef Laumen, Siemens | Josef.Laumen@SAL.SIEMENS.DE | Rel-6 |  |  | 22.140 |  |
| 135 | 18.2 | Technical realization | 524d | 2002-09-06 A | 2004-09-08 | 70% | 157.2d | 2002-09-06 | 2004-09-10 | 526d | 330d | finish no earlier than 2004-09-08 | T2 | 4192h | 2934.4h |  |  | Josef Laumen, Siemens | Josef.Laumen@SAL.SIEMENS.DE | Rel-6 | TSG | Friedhelm | 23.140 |  |
| 136 | 18.3 | OMA dependencies | 252.85d | 2003-08-15 A | 2004-09-30 | 15% | 214.92d | 2003-08-15 | 2004-08-27 | 228.85d | 314d | finish no earlier than 2004-09-30 | T2 | 2022.8h | 303.42h |  |  |  |  | Rel-6 | n/a | Friedhelm | OMA specs |  |
| 137 | 18.4 | MMS formats and codecs | 546d | 2002-08-15 A | 2004-09-16 | 75% | 136.5d | 2002-08-15 | 2004-09-16 | 546d | 324d | finish no earlier than 2004-09-16 | S4 | 4368h | 3276h | MMS6-Codec |  | Roberto Castagno (Nokia) | roberto.castagno@nokia.com | Rel-6 |  | Paolo | 26.140 |  |
| 138 | 18.5 | Handling of private addressing schemes in MMS | 196d | 2003-12-10 A | 2004-09-08 | 40% | 117.6d | 2003-12-10 | 2004-06-04 | 128d | 330d | finish no earlier than 2004-09-08 | T2 | 1568h | 627.2h |  |  | Matthias Röbke, T-Mobile | Matthias.Roebke@t-mobile.de | Rel-6 | TSG | Friedhelm | 23.140 |  |
| 139 | 18.6 | FS Multiple MMS Relay/Server Architecture | 196d | 2003-12-10 A | 2004-09-08 | 30% | 137.2d | 2003-12-10 | 2004-06-04 | 128d | 330d | finish no earlier than 2004-09-08 | T2 | 1568h | 470.4h |  |  | Juan Gorospe, Telefónica Móviles | gorospe_j@tsm.es | Rel-6 | TSG | Friedhelm | probably Annex to 23.140 |  |
| 140 | 19 | **Rel-6 MExE enhancements** | 326d | 2002-03-08 A | 2003-06-06 A | 100% |  | 2002-03-08 | 2003-06-06 | 326d |  |  | T2 | 7328h | 7328h | MEXE6 | Ter |  |  | Rel-6 | TSG | Friedhelm |  |  |
| 141 | 19.1 | MExE Rel-6 Improvements and Investigations | 264d | 2002-03-08 A | 2003-03-12 A | 100% |  | 2002-03-08 | 2003-03-12 | 264d |  | finish no earlier than 2003-03-12 | T2 | 2112h | 2112h | MEXE6-ENHANC | Ter | Lars Brenk (TTPCom) | lsb_ttpcom@HOTMAIL.COM | Rel-6 | TSG |  | 22.057, 23.057 |  |
| 142 | 19.2 | MExE Run-Time Independent Framework Feasibility Study | 326d | 2002-03-08 A | 2003-06-06 A | 100% |  | 2002-03-08 | 2003-06-06 | 326d |  | finish no earlier than 2003-06-06 | T2 | 2608h | 2608h | MEXE6-RTIF | Ter | Aaron Cohen (Intel) | Aaron.Cohen@intel.com | Rel-6 | TSG |  | 22.857 |  |
| 143 | 21 | Subscription Management | 520d | 2002-09-20 A | 2004-09-16 | 85% | 78d | 2002-09-20 | 2004-09-16 | 520d | 324d | finish no earlier than 2004-09-16 | S5 | 4160h | 3536h | SuM |  | Istvan ABA (T-Mobile Austria) | istvan.aba@t-mobile.at | Rel-6 | TSG | Adrian | 32.140/1, 32.171/2 |  |
| 144 | 22 | **Presence Capability** | 967d? | 2001-03-19 A | 2004-11-30 | 50% | 479.41d? | 2001-03-19 | 2004-12-31 | 990d? | 271d |  | S1 | 31552h | 15909.5h | PRESNC |  | Mark Cataldo, Motorola |  | Rel-6 | TSG | Michael |  | 11004 |
| 145 | 22.1 | Stage 1 | 610d | 2001-03-19 A | 2003-07-18 A | 100% |  | 2001-03-19 | 2003-07-18 | 610d |  | finish no earlier than 2003-07-18 | S1 | 4880h | 4880h |  |  |  |  | Rel-6 |  |  |  | 11005 |
| 146 | 22.2 | Stage 2 | 268d | 2001-09-12 A | 2002-09-20 A | 100% |  | 2001-09-12 | 2002-09-20 | 268d |  | finish no earlier than 2002-09-20 | S2 | 2144h | 2144h |  |  | Balazs BERTENYI, Nokia | Balazs.Bertenyi@nokia.com | Rel-6 | TSG |  |  |  |
| 147 | 22.3 | Stage 3 | 638d | 2002-04-01 A | 2004-09-08 | 90% | 63.8d | 2002-04-01 | 2004-09-08 | 638d | 330d | finish no earlier than 2004-09-08 | N1 | 5104h | 4593.6h |  |  | Keith Drage, Lucent | drage@lucent.com | Rel-6 |  |  |  |  |
| 148 | 21.4 | Stage 3 (CN3 Part Pk interface) | 638d? | 2002-04-01 | 2004-09-08 |  |  | 2002-04-01 | 2004-09-08 | 638d? | 330d | start no earlier than 2002-04-01 | N3 | 5104h |  |  |  |  |  | Rel-6 |  |  |  |  |
| 149 | 21.5 | Media Codecs and Formats for IMS Messaging and Presence | 331d? | 2003-06-12 A | 2004-09-16 | 10% | 297.9d? | 2003-06-12 | 2004-09-16 | 331d? | 324d | finish no earlier than 2004-09-16 | S4 | 2648h | 264.8h | PRESNC-COFIMP |  | Harri Honko (Nokia) | harri.honko@nokia.com | Rel-6 | TSG | Paolo | TS 26.141 |  |
| 150 | 22.4 | Security issues | 79d | 2002-08-26 A | 2002-12-12 | 20% | 63.2d | 2002-08-26 | 2002-12-12 | 79d | 784d | finish no earlier than 2002-12-12 | S3 | 632h | 126.4h |  |  |  |  | Rel-6 |  |  |  |  |
| 151 | 22.5 | USIM issues | 79d | 2002-03-04 | 2002-06-20 |  |  | 2002-03-04 | 2002-06-20 | 79d | 909d | start no earlier than 2002-03-04 | T3 | 632h |  |  |  |  |  | Rel-6 |  |  |  |  |
| 152 | 21.8 | TR on Presence and Availability Management | 95d | 2004-05-03 | 2004-09-10 |  |  | 2004-05-03 | 2004-12-31 | 175d | 328d | finish no earlier than 2004-09-10 | N5 | 760h |  |  |  |  |  | Rel-6 | TSG |  | 29.998-14 |  |
| 153 | 21.9 | SIMPLE Presence | 239d? | 2004-01-01 | 2004-11-30 |  |  | 2004-01-01 | 2004-11-30 | 239d? | 271d | finish no earlier than 2004-11-30 | OMA | 1912h |  |  |  |  | OMA-LIAISON@mail.openmobilealliance.org | Rel-6 | n/a |  |  |  |
| 154 | 25 | **Enhanced A/Gb feasibility study** | 51d? | 2002-08-30 A | 2002-11-08 | 75% | 12.75d? | 2002-08-30 | 2002-11-08 | 51d? | 808d |  | GP | 4080h | 3162h | AGbEnFS |  | J-L Carrizo, Vodafone | jose-luis.carrizo@vodafone.co.uk | Rel-6 | TSG | Paolo |  |  |
| 155 | 25.1 | **Feasibility study on A/Gb enhancements** | 51d? | 2002-08-30 A | 2002-11-08 | 75% | 12.75d? | 2002-08-30 | 2002-11-08 | 51d? | 808d |  | G2 | 3672h | 2856h | AGbEnFS-FS |  |  |  | Rel-6 | TSG |  |  |  |
| 156 | 25.1.1 | Requirements for the support of conversational services | 51d | 2002-08-30 A | 2002-11-08 A | 100% |  | 2002-08-30 | 2002-11-08 | 51d |  | finish no earlier than 2002-11-08 | GP | 408h | 408h |  |  |  |  | Rel-6 |  |  |  |  |
| 157 | 22.1.2 | Identification of the different building blocks for the provision of conversational services on the existing A/Gb protocol stack | 51d? | 2002-08-30 A | 2002-11-08 A | 100% |  | 2002-08-30 | 2002-11-08 | 51d? |  | finish no earlier than 2002-11-08 | GP | 408h | 408h |  |  |  |  | Rel-6 |  |  |  |  |
| 158 | 22.1.3 | Outline of impact and feasibility of these building blocks and their different solutions | 51d? | 2002-08-30 A | 2002-11-08 A | 100% |  | 2002-08-30 | 2002-11-08 | 51d? |  | finish no earlier than 2002-11-08 | GP | 408h | 408h |  |  |  |  | Rel-6 |  |  |  |  |
| 159 | 25.1.2 | Identification of the different building blocks for the provision of conversational services on the existing A/Gb protocol stack | 51d | 2002-08-30 | 2002-11-08 |  |  | 2002-08-30 | 2002-11-08 | 51d | 808d | finish no earlier than 2002-11-08 | G2 | 408h |  |  |  |  |  | Rel-6 |  |  |  |  |
| 160 | 25.1.3 | Outline of impact and feasibility of these building blocks and their different solutions | 51d | 2002-08-30 | 2002-11-08 |  |  | 2002-08-30 | 2002-11-08 | 51d | 808d | finish no earlier than 2002-11-08 | G2 | 408h |  |  |  |  |  | Rel-6 |  |  |  |  |
| 161 | 25.1.4 | Impact on 3GPP architecture and requirement to co-ordinatge with other TSGs (CN, SA) | 51d | 2002-08-30 A | 2002-11-08 A | 100% |  | 2002-08-30 | 2002-11-08 | 51d |  | finish no earlier than 2002-11-08 | GP | 408h | 408h |  |  |  |  | Rel-6 |  |  |  |  |
| 162 | 25.1.5 | Standardisation effort | 51d | 2002-08-30 A | 2002-11-08 A | 100% |  | 2002-08-30 | 2002-11-08 | 51d |  | finish no earlier than 2002-11-08 | GP | 408h | 408h |  |  |  |  | Rel-6 |  |  |  |  |
| 163 | 25.1.6 | Dependency to other features | 51d | 2002-08-30 A | 2002-11-08 A | 100% |  | 2002-08-30 | 2002-11-08 | 51d |  | finish no earlier than 2002-11-08 | GP | 408h | 408h |  |  |  |  | Rel-6 |  |  |  |  |

Notes:
- 139: originally it was intended to create a FS TR but most likely the work will become an Annex of 23.140
- 144: A Sultan merged "Presence Service Enhancements" (UID31028, PRES1) to this feature as no answer was provided on why Presence and Presence Encmts had same target completion date
- 148: No Contributions so far
- 149: Also for 31022 IMS Messaging
- 150: LSs handled in SA3. WID approved SA#17 Contribution at S3#25 & following e-mail discussion.
- 152: CN#24: NO resource in CN5. Companies supporting the Presence WID (NP-030302) are asked for resources. If no resource, WT should be deleted from the Presence WID / WP).
- 153: Updated according to SP-040232
- 154: Closed

| ID | WBS | Task | Duration | Start | Finish | Complete | Remaining | Baseline start | Baseline finish | Baseline duration | Total slack | Constraint | Resources | Work | Actual work | Text1 | Text4 | Text5 | Text6 | Text7 | Text8 | Text3 | Text9 |
| --- | --- | --- | --- | --- | --- | --- | --- | --- | --- | --- | --- | --- | --- | --- | --- | --- | --- | --- | --- | --- | --- | --- | --- |
| 164 | 26 | **Flexible Layer One for GERAN** | 1270d | 2000-01-03 A | 2004-11-12 | 93% | 83.34d | 2000-01-03 | 2004-06-25 | 1170d | 283d |  | GP | 81983h | 61035.7h | FLOGER | Benoist Sébire | benoist.sebire@nokia.com | Rel-6 | TSG | Paolo |  |  |
| 165 | 26.1 | **Realisation of a Flexible Layer One** | 1125d | 2000-01-03 A | 2004-04-23 A | 100% |  | 2000-01-03 | 2004-04-23 | 1125d |  |  | GP | 42808h | 42808h | FLOGER-Real | Benoist Sébire | benoist.sebire@nokia.com | Rel-6 |  |  |  |  |
| 166 | 26.1.1 | Technical Report | 471d | 2002-04-19 A | 2004-02-06 A | 100% |  | 2002-04-19 | 2004-02-06 | 471d |  | finish no earlier than 2004-02-06 | GP | 3768h | 3768h |  |  |  | Rel-6 |  |  |  |  |
| 167 | 26.1.2 | Architecture in 45.001 and 43.051 | 526d | 2002-04-19 A | 2004-04-23 A | 100% |  | 2002-04-19 | 2004-04-23 | 526d |  | finish no earlier than 2004-04-23 | G1 | 4208h | 4208h |  |  |  | Rel-6 |  |  |  |  |
| 168 | 26.1.3 | Multiplexing in 45.002 | 526d | 2002-04-19 A | 2004-04-23 A | 100% |  | 2002-04-19 | 2004-04-23 | 526d |  | finish no earlier than 2004-04-23 | G1 | 4208h | 4208h |  |  |  | Rel-6 |  |  |  |  |
| 169 | 26.1.4 | Channel Coding in 45.003 | 526d | 2002-04-19 A | 2004-04-23 A | 100% |  | 2002-04-19 | 2004-04-23 | 526d |  | finish no earlier than 2004-04-23 | G1 | 4208h | 4208h |  |  |  | Rel-6 |  |  |  |  |
| 170 | 26.1.5 | Performance Requirements in 45.005 | 1125d | 2000-01-03 A | 2004-04-23 A | 100% |  | 2000-01-03 | 2004-04-23 | 1125d |  | finish no earlier than 2004-04-23 | G1 | 9000h | 9000h |  |  |  | Rel-6 |  |  |  |  |
| 171 | 26.1.6 | Radio subsystem link control in 45.008 | 526d | 2002-04-19 A | 2004-04-23 A | 100% |  | 2002-04-19 | 2004-04-23 | 526d |  | finish no earlier than 2004-04-23 | G1 | 4208h | 4208h |  |  |  | Rel-6 |  |  |  |  |
| 172 | 26.1.7 | Requirements in 44.004 | 526d | 2002-04-19 A | 2004-04-23 A | 100% |  | 2002-04-19 | 2004-04-23 | 526d |  | finish no earlier than 2004-04-23 | G2 | 4208h | 4208h |  |  |  | Rel-6 |  |  |  |  |
| 173 | 26.2 | **Signalling and protocol support for a Flexible Layer One** | 571d | 2002-04-19 A | 2004-06-25 | 99% | 0d | 2002-04-19 | 2004-06-25 | 571d | 0d |  | G2 | 13704h | 10134.4h | FLOGER-SigPro | Benoist Sébire | benoist.sebire@nokia.com | Rel-6 |  |  |  |  |
| 174 | 26.2.1 | Modifications to RLC/MAC in 44.060 and 44.160 | 571d | 2002-04-19 A | 2004-06-25 A | 100% |  | 2002-04-19 | 2004-06-25 | 571d |  | finish no earlier than 2004-06-25 | G2 | 4568h | 4568h |  |  |  | Rel-6 |  |  |  |  |
| 175 | 26.2.2 | Modifications to RRC in 44.118 and 44.018 | 571d | 2002-04-19 A | 2004-06-25 A | 100% |  | 2002-04-19 | 2004-06-25 | 571d |  | finish no earlier than 2004-06-25 | G2 | 4568h | 4568h |  |  |  | Rel-6 |  |  |  |  |
| 176 | 26.3 | **Security for a Flexible Layer One** | 356d | 2002-04-19 A | 2003-08-29 A | 100% |  | 2002-04-19 | 2003-08-29 | 356d |  |  | S3, G2 | 5663.04h | 5663.04h | FLOGER-SecFLO | Benoist Sébire | benoist.sebire@nokia.com | Rel-6 |  |  |  |  |
| 177 | 26.3.1 | Ciphering in 44.160,44.118, 44.060 and 44.018 | 356d | 2002-04-19 A | 2003-08-29 A | 100% |  | 2002-04-19 | 2003-08-29 | 356d |  | finish no earlier than 2003-08-29 | S3, G2 | 2848h | 2848h |  |  |  | Rel-6 |  |  |  |  |
| 178 | 26.4 | **GERAN MS Conformance test for the Flexible Layer One** | 201d | 2004-02-06 | 2004-11-12 |  |  | 2004-02-06 | 2004-06-25 | 101d | 283d |  | G4; G5 | 6432h |  | FLOGER-Msconf | Benoist Sébire | benoist.sebire@nokia.com | Rel-6 |  |  |  |  |
| 179 | 26.4.1 | MS Test in 51.010 | 201d | 2004-02-06 | 2004-11-12 |  |  | 2004-02-06 | 2004-06-25 | 101d | 283d | finish no earlier than 2004-11-12 | G4; G5 | 3216h |  |  |  |  | Rel-6 |  |  |  |  |
| 180 | 26.5 | **GERAN BTS Conformance test for the Flexible Layer One** | 201d | 2004-02-06 | 2004-11-12 |  |  | 2004-02-06 | 2004-06-25 | 101d | 283d |  | G3 | 3216h |  | FLOGER-BTSconf | Benoist Sébire | benoist.sebire@nokia.com | Rel-6 |  |  |  |  |
| 181 | 26.5.1 | BTS Test in 51.021 | 201d | 2004-02-06 | 2004-11-12 |  |  | 2004-02-06 | 2004-06-25 | 101d | 283d | finish no earlier than 2004-11-12 | G3 | 1608h |  |  |  |  | Rel-6 |  |  |  |  |
| 182 | 27 | Uplink TDOA feasibility study | 151d | 2001-11-30 A | 2002-06-28 A | 100% |  | 2001-11-30 | 2002-06-28 | 151d |  | finish no earlier than 2002-06-28 | GP | 1208h | 1208h | TDOAF | Bob Gross, TruePosition, Inc. | rlgross@trueposition.com | Rel-6 |  | Paolo | 45.811 |  |
| 183 | 28 | **Multimedia Broadcast and Multicast Service** | 940d? | 2001-05-11 A | 2004-12-16 | 55% | 420.99d? | 2001-05-11 | 2004-12-16 | 940d? | 259d |  | S1 | 107546h | 51930.1h | MBMS |  |  | Rel-6 | TSG | Michael |  |  |
| 184 | 28.1 | Stage 1 | 232d | 2001-05-11 A | 2002-04-01 A | 100% |  | 2001-05-11 | 2002-04-01 | 232d |  | finish no earlier than 2002-04-01 | S1 | 1856h | 1856h |  |  |  | Rel-6 |  |  | 22.146, 22.101 | 11003 |
| 185 | 28.2 | **Stage 2** | 648d | 2001-09-24 A | 2004-03-17 | 99% | 0d | 2001-09-24 | 2004-03-17 | 648d | 0d |  | S2 | 10408h | 6548.8h |  |  |  | Rel-6 | TSG |  |  |  |
| 186 | 28.2.1 | TR on Architectural Study | 240d | 2001-09-24 A | 2002-08-23 A | 100% |  | 2001-09-24 | 2002-08-23 | 240d |  | finish no earlier than 2002-08-23 | S2 | 1920h | 1920h |  |  |  | Rel-6 |  |  | 23.846 |  |
| 187 | 28.2.2 | Stage 2 Specification Work. (User Service aspects may impact) (progress will be check in Friday of S2 #38 !!) | 413d | 2002-08-19 A | 2004-03-17 A | 100% |  | 2002-08-19 | 2004-03-17 | 413d |  | finish no earlier than 2004-03-17 | S2 | 3304h | 3304h |  |  |  | Rel-6 |  |  | 23.246 |  |
| 188 | 28.3 | Introduction of MBMS in RAN | 771d | 2002-01-01 A | 2004-12-15 | 80% | 154.2d | 2002-01-01 | 2004-09-15 | 707d | 261d | finish no earlier than 2004-12-15 | R2 | 6168h | 4934.4h | MBMS-RAN | Juho Pirskanen , Nokia | juho.pirskanen@nokia.com | Rel-6 | TSG | MCC_RAN | TS 25.346, TS 25.304, 25.321, 25.322, 25.323, 25.331 | 2481 |
| 189 | 28.4 | Support of the MBMS in CN protocols | 582d | 2002-06-18 A | 2004-09-08 | 78% | 128.04d | 2002-06-18 | 2004-09-08 | 582d | 330d | finish no earlier than 2004-09-08 | N1 | 4656h | 3631.68h |  |  |  | Rel-6 | TSG |  |  |  |
| 190 | 25.5 | Gmb interface for MBMS (CN3 part) | 271d | 2003-08-29 A | 2004-09-10 | 50% | 135.5d | 2003-08-29 | 2004-09-10 | 271d | 328d | finish no earlier than 2004-09-10 | N3 | 2168h | 1084h |  |  |  | Rel-6 |  |  | 29.061 |  |
| 191 | 28.5 | Security Aspects of Multimedia Broadcast/Multicast Service (MBMS) | 324d | 2002-07-01 A | 2003-09-25 | 20% | 259.2d | 2002-07-01 | 2003-09-25 | 324d | 579d | finish no earlier than 2003-09-25 | S3 | 2592h | 518.4h | MBMS | Escott, Adrian, 3 | adrian.escott@three.co.uk | Rel-6 | TSG |  |  |  |

Notes:
- 164: Nokia, Ericsson, Siemens, Telia
- 165: Completed
- 173: Completed
- 176: Started
- 178: Not started
- 180: Not started
- 183: Title renamed at SA#13
- 184: This may or may not be a separate stage 1. In the meantime, CRs are proposed for 22.101
- 191: WID approved SA#17

| ID | WBS | Task | Duration | Start | Finish | Complete | Remaining | Baseline start | Baseline finish | Baseline duration | Total slack | Constraint | Resources | Work | Actual work | Text1 | Text6 | Text7 | Text3 | Text8 | Text9 | Text4 | Text5 |
| --- | --- | --- | --- | --- | --- | --- | --- | --- | --- | --- | --- | --- | --- | --- | --- | --- | --- | --- | --- | --- | --- | --- | --- |
| 192 | 28.6 | **Support of MBMS in GERAN** | 837d? | 2001-08-30 A | 2004-11-12 | 46% | 450.93d? | 2001-08-30 | 2004-11-12 | 837d? | 283d |  | GP | 64080h | 27617.5h | MBMS-GERAN | Rel-6 | TSG |  |  |  |  |  |
| 193 | 28.6.1 | Impact on the logical and physical channels | 576d | 2002-08-30 A | 2004-11-12 | 50% | 288d | 2002-08-30 | 2004-11-12 | 576d | 283d | finish no earlier than 2004-11-12 | GP | 4608h | 2304h |  | Rel-6 |  |  |  |  |  |  |
| 194 | 28.6.4 | Re-synchronisation at cell change | 576d | 2002-08-30 A | 2004-11-12 | 50% | 288d | 2002-08-30 | 2004-11-12 | 576d | 283d | finish no earlier than 2004-11-12 | G2 | 4608h | 2304h |  | Rel-6 |  |  |  |  |  |  |
| 195 | 25.7.3 | Simultaneous support of MBMS services | 576d? | 2002-08-30 A | 2004-11-12 | 50% | 288d? | 2002-08-30 | 2004-11-12 | 576d? | 283d | finish no earlier than 2004-11-12 | GP | 4608h | 2304h |  | Rel-6 |  |  |  |  |  |  |
| 196 | 25.7.4 | Simultaneous support of MBMS and non-MBMS services | 837d? | 2001-08-30 A | 2004-11-12 | 50% | 418.5d? | 2001-08-30 | 2004-11-12 | 837d? | 283d | finish no earlier than 2004-11-12 | GP | 6696h | 3348h |  | Rel-6 |  |  |  |  |  |  |
| 197 | 25.7.5 | Resynchronisation at cell change | 837d? | 2001-08-30 A | 2004-11-12 | 50% | 418.5d? | 2001-08-30 | 2004-11-12 | 837d? | 283d | finish no earlier than 2004-11-12 | GP | 6696h | 3348h |  | Rel-6 |  |  |  |  |  |  |
| 198 | 28.6.5 | Decision making process between point-to-point or pont-to-multipoint configurations | 576d | 2002-08-30 A | 2004-11-12 | 50% | 288d | 2002-08-30 | 2004-11-12 | 576d | 283d | finish no earlier than 2004-11-12 | GP | 4608h | 2304h |  | Rel-6 |  |  |  |  |  |  |
| 199 | 28.6.6 | MBMS channel allocations procedures to multiple MSs | 576d | 2002-08-30 A | 2004-11-12 | 50% | 288d | 2002-08-30 | 2004-11-12 | 576d | 283d | finish no earlier than 2004-11-12 | GP | 4608h | 2304h |  | Rel-6 |  |  |  |  |  |  |
| 200 | 28.6.7 | Changes to the Gb interface | 576d | 2002-08-30 A | 2004-11-12 | 50% | 288d | 2002-08-30 | 2004-11-12 | 576d | 283d | finish no earlier than 2004-11-12 | GP | 4608h | 2304h |  | Rel-6 |  |  |  |  |  |  |
| 201 | 28.6.8 | GERAN specific changes to the Iu-ps interface | 576d | 2002-08-30 A | 2004-11-12 | 50% | 288d | 2002-08-30 | 2004-11-12 | 576d | 283d | finish no earlier than 2004-11-12 | GP | 4608h | 2304h |  | Rel-6 |  |  |  |  |  |  |
| 202 | 28.6.9 | Interaction between MBMS and Iu-flex | 576d | 2002-08-30 A | 2004-11-12 | 50% | 288d | 2002-08-30 | 2004-11-12 | 576d | 283d | finish no earlier than 2004-11-12 | GP | 4608h | 2304h |  | Rel-6 |  |  |  |  |  |  |
| 203 | 28.6.10 | Security aspects | 576d | 2002-08-30 A | 2004-11-12 | 50% | 288d | 2002-08-30 | 2004-11-12 | 576d | 283d | finish no earlier than 2004-11-12 | GP | 4608h | 2304h |  | Rel-6 |  |  |  |  |  |  |
| 204 | 25.7.12 | MS conformance tests- G3 | 576d? | 2002-08-30 | 2004-11-12 |  |  | 2002-08-30 | 2004-11-12 | 576d? | 283d | finish no earlier than 2004-11-12 | G3 | 4608h |  |  | Rel-6 |  |  |  |  |  |  |
| 205 | 28.1 | **MBMS User Services** | 418d? | 2003-05-13 A | 2004-12-16 | 69% | 131.58d? | 2003-05-13 | 2004-12-16 | 418d? | 259d |  | S1 | 8376h | 5739.36h |  | Rel-6 |  | 22.246 | Michael | 11003 |  |  |
| 206 | 28.1 | MBMS User Services Stage 1 | 233d | 2003-05-13 A | 2004-04-01 A | 100% |  | 2003-05-13 | 2004-04-01 | 233d |  | start no earlier than 2003-05-13 | S1 | 1864h | 1864h |  | Rel-6 |  | 22.246 | Michael | 11003 |  |  |
| 207 | 25.8.2 | Definition of MBMS user services, media codecs, formats and transport/application protocols using MBMS | 396d? | 2003-06-12 A | 2004-12-16 | 50% | 198d? | 2003-06-12 | 2004-12-16 | 396d? | 259d | finish no earlier than 2004-12-16 | S4 | 3168h | 1584h | MBMS-TSMBMS | Rel-6 | TSG | 26.346 | Paolo |  | Igor Curcio (Nokia) | igor.curcio@nokia.com |
| 208 | 29 | **Speech Recognition and Speech Enabled Services** | 699d? | 2001-10-08 A | 2004-06-10 | 97% | 20.8d? | 2001-10-08 | 2004-06-10 | 699d? | 394d |  | S1 | 11680h | 11332.4h | SRSES | Rel-6 | TSG |  | Michael |  |  |  |
| 209 | 29.1 | Speech Enabled Services Based on Distributed Speech Recognition (DSR) | 115d | 2001-10-08 A | 2002-03-15 A | 100% |  | 2001-10-08 | 2002-03-15 | 115d |  | finish no earlier than 2002-03-15 | S1 | 920h | 920h | DSR | Rel-6 | TSG | 22.941, 23.207, 22.243 |  |  | D Williams, QUALCOMM, Inc. | Dwilliams@qualcomm.com |
| 210 | 29.2 | TR on Architectural impacts | 212d | 2003-05-12 A | 2004-03-02 A | 100% |  | 2003-05-12 | 2004-03-02 | 212d |  | finish no earlier than 2004-03-02 | S2 | 1696h | 1696h |  | Rel-6 |  | 23.877 |  |  |  |  |
| 211 | 26.3 | Codec Work to Support Speech Recognition Framework for Automated Voice Services | 433d? | 2002-10-15 A | 2004-06-10 | 95% | 21.65d? | 2002-10-15 | 2004-06-10 | 433d? | 394d | finish no earlier than 2004-06-10 | S4 | 3464h | 3290.8h | SRSES-Codec | Rel-6 | WG | 26.235, 26.236, 26.243 | Paolo |  | David Pearce, Motorola | bdp003@motorola.com |
| 212 | 26.4 | Multimodal support | 1d? | 2004-01-01 | 2004-01-01 |  |  | 2004-01-01 | 2004-01-01 | 1d? | 509d | start no earlier than 2004-01-01 | OMA | 8h |  |  | Rel-6 |  |  |  |  |  | OMA-LIAISON@mail.openmobilealliance.org |
| 213 | 30 | **Generic User Profile** | 822d | 2001-10-08 A | 2004-11-30 | 68% | 259.15d | 2001-10-08 | 2004-11-30 | 822d | 271d |  | S1 | 24807.8h | 16986.7h | GUP | Rel-6 | TSG |  | Michael |  |  |  |
| 214 | 30.1 | Stage 1 - Requirements | 430d | 2001-10-08 A | 2003-05-30 A | 100% |  | 2001-10-08 | 2003-05-30 | 430d |  | finish no earlier than 2002-12-09 | S1 | 3440h | 3440h |  | Rel-6 |  | 22.240, 22.228 |  |  | Paul Amery (Orange) | paul.amery@orange.co.uk |
| 215 | 30.3 | Stage 2 - Architecture | 355d | 2002-01-28 A | 2003-06-06 A | 100% |  | 2002-01-28 | 2003-06-06 | 355d |  | finish no earlier than 2003-06-06 | S2 | 2840h | 2840h |  | Rel-6 |  | 23.240 |  |  | Harri KOSKINEN, Nokia | harri.o.koskinen@nokia.com |
| 216 | 30.2 | Stage 2 - Data Description Method | 327d | 2002-12-05 A | 2004-03-05 | 90% | 32.7d | 2002-12-05 | 2004-03-05 | 327d | 463d | finish no earlier than 2004-03-05 | T2 | 2616h | 2354.4h |  | Rel-6 | TSG | 23.241 | Friedhelm |  | Kurt Bischinger (T-Mobile AUSTRIA) | kurt.bischinger@t-mobile.at |
| 217 | 30.4 | Stage 3 - Common objects | 457d | 2002-12-05 A | 2004-09-03 | 60% | 182.8d | 2002-12-05 | 2004-09-03 | 457d | 333d | finish no earlier than 2004-09-03 | T2 | 3656h | 2193.6h |  | Rel-6 | TSG | 24.241 | Friedhelm |  |  |  |
| 218 | 30.5 | Stage 3 - Network | 401.98d | 2003-05-19 A | 2004-11-30 | 40% | 241.19d | 2003-05-19 | 2004-11-30 | 401.98d | 271d | finish no earlier than 2004-11-30 | N4 | 3215.84h | 1286.34h |  | Rel-6 |  | 29.240 |  |  |  |  |
| 219 | 30.6 | Security Aspects | 308d | 2002-07-16 A | 2003-09-18 | 15% | 261.8d | 2002-07-16 | 2003-09-18 | 308d | 584d | finish no earlier than 2003-09-18 | S3 | 2464h | 369.6h |  | Rel-6 | WG | 33.102, 33.203, 33.210 |  |  | Owen, Bradley | bvowen@lucent.com |

Notes:
- 218: 17 May no activity in CN4.........
- 219: WID approved SA#17. SA WG3 progress slow, depends on progress in other groups.

| ID | WBS | Task | Duration | Start | Finish | Complete | Remaining | Baseline start | Baseline finish | Baseline duration | Total slack | Constraint | Resources | Work | Actual work | Text1 | Text6 | Text7 | Text8 | Text4 | Text5 | Text3 | Text9 | Text10 | Text11 | Text12 |
| --- | --- | --- | --- | --- | --- | --- | --- | --- | --- | --- | --- | --- | --- | --- | --- | --- | --- | --- | --- | --- | --- | --- | --- | --- | --- | --- |
| 220 | 31 | **Digital Rights Management** | 690d? | 2001-10-08 A | 2004-05-28 | 39% | 422.65d? | 2001-10-08 | 2004-05-28 | 690d? | 403d |  | S1 | 11392h | 4414.01h | DRM | Rel-6 | TSG | Michael |  |  |  |  |  |  |  |
| 221 | 31.1 | Requirements | 179d | 2001-10-08 A | 2002-06-13 A | 100% |  | 2001-10-08 | 2002-06-13 | 179d |  | finish no earlier than 2002-06-13 | S1 | 1432h | 1432h |  | Rel-6 |  |  | Nicholas Wood, Openwave Systems | nicholas.wood@openwave.com |  |  |  |  |  |
| 222 | 28.2 | Monitoring of Stages 2 and 3 progress (actual work to be done by OMA) | 155d? | 2002-08-19 A | 2003-03-21 | 20% | 124d? | 2002-08-19 | 2003-03-21 | 155d? | 713d | start no earlier than 2002-08-19 | S1 | 1240h | 248h |  | Rel-6 |  |  |  |  |  |  |  |  |  |
| 223 | 31.3 | Monitoring of Security (work done by OMA) | 186d | 2002-06-17 A | 2003-03-03 | 40% | 111.6d | 2002-06-17 | 2003-03-03 | 186d | 727d | finish no earlier than 2003-03-03 | S3 | 1488h | 595.2h |  | Rel-6 |  |  |  |  |  |  |  |  |  |
| 224 | 28.4 | Stage 2 | 107d? | 2004-01-01 | 2004-05-28 |  |  | 2004-01-01 | 2004-05-28 | 107d? | 403d | finish no earlier than 2004-05-28 | OMA | 856h |  |  | Rel-6 |  |  |  | OMA-LIAISON@mail.openmobilealliance.org |  |  |  |  |  |
| 225 | 28.5 | Stage 3 | 107d? | 2004-01-01 | 2004-05-28 |  |  | 2004-01-01 | 2004-05-28 | 107d? | 403d | finish no earlier than 2004-05-28 | OMA | 856h |  |  | Rel-6 |  |  |  | OMA-LIAISON@mail.openmobilealliance.org |  |  |  |  |  |
| 226 | 32 | **WLAN-UMTS Interworking** | 1239d? | 2000-01-03 A | 2004-09-30 | 80% | 242.44d? | 2000-01-03 | 2004-09-30 | 1239d? | 314d |  | S1 | 38456h | 31111.3h | WLAN | Rel-6 | TSG | Michael | Fredric Paint, Telenor | frederic.paint@telenor.com |  |  |  |  |  |
| 227 | 32.1 | Technical Report | 900d? | 2000-01-03 A | 2003-06-13 A | 100% |  | 2000-01-03 | 2003-06-13 | 900d? |  | finish no earlier than 2003-06-13 | S1 | 7200h | 7200h | WLAN-TR | Rel-6 |  |  | Fredric Paint, Telenor | frederic.paint@telenor.com | 22.934, 22.101, 22.105 |  |  |  |  |
| 228 | 29.2 | **Stage 1** | 375d? | 2003-01-06 A | 2004-06-11 | 76% | 90.88d? | 2000-01-03 | 2004-06-11 | 1160d? | 393d |  | S1 | 4840h | 3890h | WLAN-TS | Rel-6 |  |  | Fredric Paint, Telenor | frederic.paint@telenor.com | 22.234 |  |  |  |  |
| 229 | 29.2.1 | Global stage 1 | 375d? | 2003-01-06 A | 2004-06-11 | 99% | 3.75d? |  |  |  | 393d | finish no earlier than 2004-06-11 | S1 | 3000h | 2970h | WLAN-TS | Rel-6 |  |  | Fredric Paint, Telenor | frederic.paint@telenor.com | 22.234 |  |  |  |  |
| 230 | 29.2.2 | Session Continuity | 115d? | 2004-01-05 | 2004-06-11 |  |  |  |  |  | 393d | start no earlier than 2004-01-05 | S1 | 920h |  | WLAN-SC | Rel-7 |  |  |  |  |  |  |  |  |  |
| 231 | 32.2 | Architecture Definition for scenarii 2 and 3 | 571d | 2002-03-25 A | 2004-05-31 A | 100% |  | 2002-03-25 | 2004-05-31 | 571d |  | finish no earlier than 2004-05-31 | S2 | 4568h | 4568h |  | Rel-6 | TSG |  |  |  | 23.234 |  |  |  |  |
| 232 | 32.3 | Security | 125d | 2002-09-30 A | 2003-03-21 | 30% | 87.5d | 2002-09-30 | 2003-03-21 | 125d | 713d | finish no earlier than 2003-03-21 | S3 | 1000h | 300h |  | Rel-6 | TSG |  | Lopez-Soria, Luis, Ericsson | luis.lopez-soria@ece.ericsson.se | 21.133, 33.106, 33.107, 33.108, 33.200, 33.203, 33.210 |  |  |  |  |
| 233 | 29.5 | Stage 3 - CN4 aspects | 334d? | 2003-05-23 A | 2004-09-01 | 77% | 76.82d? | 2003-05-23 | 2004-09-01 | 334d? | 335d | finish no earlier than 2004-09-01 | N4 | 2672h | 2057.44h | WLAN-IW | Rel-6 | TSG |  | Rodriguez ,Raquel, Nokia | raquel.rodriguez@nokia.com | 29.234, 29.061 |  |  |  |  |
| 234 | 29.6 | Stage 3 - CN3 aspects (Wi Interface for Scenario 3) | 355d? | 2003-05-23 A | 2004-09-30 | 68% | 114.6d? | 2003-05-23 | 2004-09-30 | 355d? | 314d | start no earlier than 2003-05-23 | N3 | 2840h | 1923.2h | WLAN | Rel-6 | TSG |  |  |  | 29.161 |  |  |  |  |
| 235 | 29.7 | Stage 3 for scenario 2 | 339d? | 2003-05-23 A | 2004-09-08 | 78% | 74.58d? | 2003-05-23 | 2004-09-08 | 339d? | 330d | finish no earlier than 2004-09-08 | N1 | 2712h | 2115.36h |  | Rel-6 | WG |  |  |  |  |  |  |  |  |
| 236 | 29.8 | Stage 3 for scenario 3 | 339d? | 2003-05-23 A | 2004-09-08 | 40% | 203.4d? | 2003-05-23 | 2004-09-08 | 339d? | 330d | start no earlier than 2003-05-23 | N1 | 2712h | 1084.8h |  | Rel-6 | WG |  |  |  |  |  |  |  |  |
| 237 | 33 | **Priority Service** | 666d? | 2002-05-30 A | 2004-12-16 | 61% | 260.04d? | 2002-05-30 | 2004-12-16 | 666d? | 259d |  | S1 | 12616h | 7690.01h | PRIOR | Rel-6 | TSG | Michael |  |  |  |  |  |  |  |
| 238 | 33.1 | Feasibility Study | 1d | 2002-06-14 A | 2002-06-14 A | 100% |  | 2002-06-14 | 2002-06-14 | 1d |  | finish no earlier than 2002-06-14 | S1 | 8h | 8h | PRIOR-FS | Rel-6 |  | Michael | Biplab K. Pramanik, Telcordia Technologies | bpramani@telcordia.com | 22.950 |  |  |  |  |
| 239 | 33.2 | Stage 1 - Requirements | 340d | 2002-05-30 A | 2003-09-17 A | 100% |  | 2002-05-30 | 2003-09-17 | 340d |  | finish no earlier than 2003-09-17 | S1 | 2720h | 2720h | PRIOR-SR | Rel-6 |  | Michael | James J. Garrahan, Telcordia Technologies | bpramani@telcordia.com |  |  |  |  |  |
| 240 | 30.3 | Multimedia Priority Service | 450d? | 2003-03-28 A | 2004-12-16 | 20% | 360d? | 2003-03-28 | 2004-12-16 | 450d? | 259d | finish no earlier than 2004-12-16 | S1 | 3600h | 720h |  | Rel-6 |  |  |  |  |  |  |  |  |  |
| 241 | 30.4 | Priority service implementation guide | 131d? | 2003-03-28 A | 2003-09-26 A | 100% |  | 2003-03-28 | 2003-09-26 | 131d? |  | finish no earlier than 2003-09-26 | S1 | 1048h | 1048h |  | Rel-6 |  |  | Biplab K. Pramanik, Telcordia Technologies | bpramani@telcordia.com | 22.952 |  |  |  |  |
| 242 | 34 | **Network Sharing** | 432d? | 2003-01-20 A | 2004-09-15 | 73% | 117.95d? | 2003-01-20 | 2005-03-17 | 563.41d? | 326d |  | S1 | 15032h | 10927.6h | NTShar | Rel-6 | TSG | Michael |  |  |  |  |  |  |  |
| 243 | 34.1 | Technical Report | 240d? | 2003-01-20 A | 2003-12-19 A | 100% |  | 2003-01-20 | 2003-12-19 | 240d? |  |  | S1 | 1920h | 1920h | NTShar-TR | Rel-6 |  | Michael |  |  | 22.951 |  |  |  |  |
| 244 | 31.2 | Stage 1 - CRs to implement Network Sharing | 240d? | 2003-01-20 A | 2003-12-19 A | 100% |  | 2003-01-20 | 2003-12-19 | 240d? |  | finish no earlier than 2003-12-19 | S1 | 1920h | 1920h | NTShar-CR | Rel-6 |  |  |  |  | 22.011, 22.101, 22.115, 22.129 |  |  |  |  |
| 245 | 31.3 | Stage 2 | 372d? | 2003-02-27 A | 2004-07-30 | 83% | 63.24d? | 2003-02-27 | 2004-07-30 | 372d? | 358d | finish no earlier than 2004-07-30 | S2 | 2976h | 2470.08h |  | Rel-6 |  |  |  |  | 23.251 |  |  |  |  |
| 246 | 31.4 | Network sharing - stage 3 | 339d? | 2003-05-23 A | 2004-09-08 | 40% | 203.4d? | 2003-05-23 | 2004-09-08 | 339d? | 330d | finish no earlier than 2004-09-08 | N1 | 2712h | 1084.8h |  | Rel-6 | WG |  |  |  |  |  |  |  |  |
| 247 | 31.5 | Enhancement of the support of network sharing in the UTRAN | 258d | 2003-09-19 A | 2004-09-15 | 50% | 129d | 2003-09-19 | 2005-03-17 | 389.41d | 326d | finish no earlier than 2004-09-15 | R2 | 2064h | 1032h | NTShar-UTRANEnh | Rel-6 | TSG | MCC_RAN | Anders Dahlén, TeliaSonera | Anders.Dahlen@TeliaSonera.com | TS25.401, TS25.413, TS25.331, TS25.304 | BB | 31018 | Active | 48 |

Notes:
- 220: Foreseen start and completion dates introduced by MCC (no indication at all on the WID)
- 223: SA3 acknowledge role in WI at SA3#20. Active contribution S3#24, S3#25. S3 WID approved SA#17
- 232: Active contribution S3#24, S3#25. WID approved SA#17
- 233: WID approved at CN#19............
- 234: WID approved at CN#19.........

| ID | WBS | Task | Duration | Start | Finish | Complete | Remaining | Baseline start | Baseline finish | Baseline duration | Total slack | Constraint | Resources | Work | Actual work | Text1 | Text6 | Text7 | Text8 | Text3 | Text5 | Text4 |
| --- | --- | --- | --- | --- | --- | --- | --- | --- | --- | --- | --- | --- | --- | --- | --- | --- | --- | --- | --- | --- | --- | --- |
| 248 | 35 | **QoS Improvements** | 565d? | 2002-07-15 A | 2004-09-10 | 89% | 64.47d? | 2002-07-15 | 2004-09-10 | 565d? | 328d |  | S2 | 12120h | 10737h | QoS1 | Rel-6 | TSG | Sang-Ui |  |  |  |
| 249 | 35.1 | FS on Dynamic Policy control enhancements for end-to-end QoS | 465d | 2002-07-15 A | 2004-04-23 A | 100% |  | 2002-07-15 | 2004-04-23 | 465d |  | finish no earlier than 2004-04-23 | S2 | 3720h | 3720h | QoS1 | Rel-6 | TSG |  | 23.917 | Claire Mousset, Nortel |  |
| 250 | 32.2 | Definition of the Gq interface | 214d? | 2003-07-01 A | 2004-04-23 A | 100% |  | 2003-07-01 | 2004-04-23 | 214d? |  | finish no earlier than 2004-04-23 | S2 | 1712h | 1712h |  | Rel-6 |  |  | 23.221 |  | Janne Rinne (Nokia) |
| 251 | 32.3 | Gq interface specification for Dynamic Policy control enhancements – Stage 3 | 271d | 2003-08-29 A | 2004-09-10 | 60% | 108.4d | 2003-08-29 | 2004-09-10 | 271d | 328d | finish no earlier than 2004-09-10 | N3 | 2168h | 1300.8h |  | Rel-6 | TSG |  | 24,228, 29.207, 29.208 | Anna.Sillanpaai@nokia.com | Anna Sillanpää, Nokia |
| 252 | 36 | **Subscriber certificates** | 722d? | 2002-02-25 A | 2004-11-30 | 54% | 332.49d? | 2002-02-25 | 2004-11-30 | 722d? | 271d |  | S3 | 12320h | 6646.47h | SEC1-SC | Rel-6 | TSG | Maurice | 33.102 | valtteri.niemi@nokia.com | Valtteri Niemi, Nokia |
| 253 | 36.1 | Stage 1 | 144d | 2002-02-25 A | 2002-09-12 | 40% | 86.4d | 2002-02-25 | 2002-09-12 | 144d | 849d | finish no earlier than 2002-09-12 | S3 | 1152h | 460.8h |  | Rel-6 |  |  |  |  |  |
| 254 | 36.2 | Architecture review | 24d | 2002-10-14 A | 2002-11-14 A | 100% |  | 2002-10-14 | 2002-11-14 | 24d |  | finish no earlier than 2002-11-14 | S2 | 192h | 192h |  | Rel-6 |  |  |  |  |  |
| 255 | 33.3 | Stage 3 | 313d? | 2003-09-19 A | 2004-11-30 | 50% | 156.5d? | 2003-09-19 | 2004-11-30 | 313d? | 271d | finish no earlier than 2004-11-30 | N4 | 2504h | 1252h | SEC1-SC | Rel-6 |  | Kimmo |  |  | Lauri Laitinen, Nokia |
| 256 | 33.4 | Stage 3 Ua & Ub interfaces | 223d? | 2003-11-03 A | 2004-09-08 | 40% | 133.8d? | 2003-11-03 | 2004-09-08 | 223d? | 330d | finish no earlier than 2004-09-08 | N1 | 1784h | 713.6h |  | Rel-6 |  |  |  |  |  |
| 257 | 33.5 | OMA dependencies on Subscriber certificates | 114d? | 2004-01-01 A | 2004-06-08 A | 100% |  | 2004-01-01 | 2004-06-08 | 114d? |  | finish no earlier than 2004-06-08 | OMA | 912h | 912h |  | Rel-6 | n/a |  |  | OMA-LIAISON@mail.openmobilealliance.org |  |
| 258 | 34 | **Rel-6 OSA enhancements** | 491d? | 2002-10-31 A | 2004-09-16 | 70% | 149.15d? | 2002-10-31 | 2004-09-30 | 501d? | 324d |  | S1 | 24607.2h | 15749.9h | OSA3 | Rel-6 | TSG | Adrian | 22.127, 29.198, 29.998 | Chelo.Abarca@alcatel.fr | Chelo ABARCA (Alcatel) |
| 259 | 34.1 | Scope of the Open Service Access Release 6 | 66d? | 2003-03-28 A | 2003-06-27 A | 100% |  | 2003-03-28 | 2003-06-27 | 66d? |  | finish no earlier than 2003-06-27 | S1 | 528h | 528h |  | Rel-6 | TSG |  |  |  |  |
| 260 | 34.2 | Multi Media Messaging function | 487d? | 2002-10-31 A | 2004-09-10 | 60% | 194.8d? | 2002-10-31 | 2004-06-18 | 427d? | 328d | finish no earlier than 2004-09-10 | N5 | 3896h | 2337.6h |  | Rel-6 | TSG |  | 29.198, 29.998 |  |  |
| 261 | 34.3 | Policy management extensions | 292d? | 2002-10-31 A | 2003-12-12 A | 100% |  | 2002-10-31 | 2003-12-12 | 292d? |  | finish no earlier than 2003-12-12 | N5 | 2336h | 2336h |  | Rel-6 | TSG |  | 29.198, 29.998 |  |  |
| 262 | 34.4 | TS on Presence and Availability Management (from the PRESNC WI) | 367d? | 2002-10-31 A | 2004-03-26 A | 100% |  | 2002-10-31 | 2004-03-26 | 367d? |  | finish no earlier than 2004-03-26 | N5 | 2936h | 2936h |  | Rel-6 | TSG |  | 29.198-14 |  |  |
| 263 | 34.5 | OSA interfaces at different levels of abstractions (Parlay X, Web services) | 305d? | 2003-07-14 A | 2004-09-10 | 90% | 30.5d? | 2003-07-14 | 2004-06-18 | 245d? | 328d | finish no earlier than 2004-09-10 | N5 | 2440h | 2196h |  | Rel-6 | TSG |  | 29.199 |  |  |
| 264 | 34.6 | Introduction of migration support mechanism | 290d? | 2002-10-31 A | 2003-12-10 A | 100% |  | 2002-10-31 | 2003-12-10 | 290d? |  | finish no earlier than 2003-12-12 | N5 | 2320h | 2320h |  | Rel-6 | TSG |  | 29.198, 29.998 |  |  |
| 265 | 34.7 | User Profile | 367d? | 2003-04-17 | 2004-09-10 |  |  | 2003-01-23 | 2004-06-18 | 367d? | 328d | start no earlier than 2003-04-17 | N5 | 2936h |  |  | Rel-6 | TSG |  | 29.198, 29.998 |  |  |
| 266 | 34.8 | Framework Function for Federation | 225d? | 2003-02-03 A | 2003-12-12 A | 100% |  | 2003-02-03 | 2003-12-12 | 225d? |  | finish no earlier than 2003-12-12 | N5 | 1800h | 1800h |  | Rel-6 | TSG |  | 29.198, 29.998 |  |  |
| 267 | 34.9 | OMA dependencies on OSA | 196d? | 2003-12-18 | 2004-09-16 |  |  | 2004-01-01 | 2004-09-30 | 196d? | 324d | start no earlier than 2003-12-18 | OMA | 1568h |  |  | Rel-6 | n/a |  |  |  |  |
| 268 | 39 | **Addition of frequency bands to GSM** | 621d | 2002-06-28 A | 2004-11-12 | 4% | 596.04d | 2002-06-28 | 2004-11-12 | 621d | 283d |  | GP | 15320h | 615.64h | TAPS | Rel-6 | TSG | Paolo |  |  | Torben Themsen |
| 269 | 39.1 | **Addition of frequency bands to GSM – Changes to core specs** | 26d | 2002-11-15 A | 2002-12-20 A | 100% |  | 2002-11-15 | 2002-12-20 | 26d |  |  | G1 | 416h | 416h | TAPS-Specs | Rel-6 | TSG |  |  |  | Torben Themsen |
| 270 | 39.1.1 | Changes to core specs | 26d | 2002-11-15 A | 2002-12-20 A | 100% |  | 2002-11-15 | 2002-12-20 | 26d |  | finish no earlier than 2002-12-20 | G1 | 208h | 208h |  | Rel-6 |  |  |  |  |  |
| 271 | 39.2 | **Addition of frequency bands to GSM – Changes for conformance tests** | 621d | 2002-06-28 | 2004-11-12 |  |  | 2002-06-28 | 2004-11-12 | 621d | 283d |  | G4 | 9936h |  | TAPS-Conf | Rel-6 |  |  |  |  | Torben Themsen |
| 272 | 39.2.1 | 51.010-1 Add testing | 621d | 2002-06-28 | 2004-11-12 |  |  | 2002-06-28 | 2004-11-12 | 621d | 283d | finish no earlier than 2004-11-12 | G4 | 4968h |  |  | Rel-6 |  |  |  |  |  |

Notes:
- 251: [DAB - 25.05.04] - Delayed to Sept - possibly Dec 2004
- 252: Approved at SA#14. This may require BBs from CN1, CN4, SA5 and T3
- 253: Contribution received S3#24, S3#25
- 255: WID approved at CN#21............
- 257: Updated according to SP-040420
- 258: CN#24: TSG Approval delayed 06/04->09/04.
- 260: CN#24: TSG Approval delayed 06/04->09/04.
- 262: N5#26: Split WI into TS & TR.
- 263: CN#24: TSG Approval delayed 06/04->09/04.
- 265: CN#24: TSG Approval delayed 06/04->09/04. Still Pending input from SA1/2.
- 267: Updated according to SP-040420
- 269: Ready
- 271: Not started

| ID | WBS | Task | Duration | Start | Finish | Complete | Remaining | Baseline start | Baseline finish | Baseline duration | Total slack | Constraint | Resources | Work | Actual work | Text1 | Text4 | Text6 | Text7 | Text8 | Text3 | Text5 | Text2 |
| --- | --- | --- | --- | --- | --- | --- | --- | --- | --- | --- | --- | --- | --- | --- | --- | --- | --- | --- | --- | --- | --- | --- | --- |
| 273 | 40 | **Seamless support of streaming services in A/Gb mode** | 1065d? | 2000-01-03 A | 2004-01-30 | 94% | 68.97d? | 2000-01-03 | 2004-01-30 | 1065d? | 488d |  | GP | 40840h | 37411.7h | SSStrea | José Luis Carrizo Martínez, Vodafone | Rel-6 | TSG | Paolo |  |  |  |
| 274 | 40.1 | **Identification of requirements for streaming** | 46d? | 2003-06-27 A | 2003-08-29 A | 100% |  | 2003-06-27 | 2003-08-29 | 46d? |  |  | G1 | 736h | 736h |  |  | Rel-6 |  |  |  |  |  |
| 275 | 36.1.1 | Requirements | 46d? | 2003-06-27 A | 2003-08-29 A | 100% |  | 2003-06-27 | 2003-08-29 | 46d? |  | finish no earlier than 2003-08-29 | G1 | 368h | 368h |  |  | Rel-6 |  |  |  |  |  |
| 276 | 40.2 | **Performance study of cell change mechanisms** | 955d? | 2000-01-03 A | 2003-08-29 A | 100% |  | 2000-01-03 | 2003-08-29 | 955d? |  |  | G1 | 30560h | 30560h |  |  | Rel-6 |  |  |  |  |  |
| 277 | 36.2.1 | Performance of NACC | 955d? | 2000-01-03 A | 2003-08-29 A | 100% |  | 2000-01-03 | 2003-08-29 | 955d? |  | finish no earlier than 2003-08-29 | G1 | 7640h | 7640h |  |  | Rel-6 |  |  |  |  |  |
| 278 | 36.2.2 | Performance of cell change in DTM for the PS domain | 955d? | 2000-01-03 A | 2003-08-29 A | 100% |  | 2000-01-03 | 2003-08-29 | 955d? |  | finish no earlier than 2003-08-29 | G1 | 7640h | 7640h |  |  | Rel-6 |  |  |  |  |  |
| 279 | 36.2.3 | Handover | 955d? | 2000-01-03 A | 2003-08-29 A | 100% |  | 2000-01-03 | 2003-08-29 | 955d? |  | finish no earlier than 2003-08-29 | G1 | 7640h | 7640h |  |  | Rel-6 |  |  |  |  |  |
| 280 | 40.3 | **Reduction of service interruption times and packet loss during mobility procedures** | 106d? | 2003-06-27 A | 2003-11-21 | 99% | 0d? | 2003-06-27 | 2003-11-21 | 106d? | 0d |  | G2 | 4240h | 3396h |  |  | Rel-6 |  |  |  |  |  |
| 281 | 36.3.1 | Optimisations of existing mechanisms/procedures | 106d? | 2003-06-27 A | 2003-11-21 A | 100% |  | 2003-06-27 | 2003-11-21 | 106d? |  | finish no earlier than 2003-11-21 | G2 | 848h | 848h |  |  | Rel-6 |  |  |  |  |  |
| 282 | 36.3.2 | Inter-system NACC | 106d? | 2003-06-27 A | 2003-11-21 A | 100% |  | 2003-06-27 | 2003-11-21 | 106d? |  | finish no earlier than 2003-11-21 | G2 | 848h | 848h |  |  | Rel-6 |  |  |  |  |  |
| 283 | 36.3.3 | PS Handover (within GERAN and between GERAN and UTRAN) | 106d? | 2003-06-27 A | 2003-11-21 A | 100% |  | 2003-06-27 | 2003-11-21 | 106d? |  | finish no earlier than 2003-11-21 | G2 | 848h | 848h |  |  | Rel-6 |  |  |  |  |  |
| 284 | 36.3.4 | Dependency to other features | 106d? | 2003-06-27 A | 2003-11-21 A | 100% |  | 2003-06-27 | 2003-11-21 | 106d? |  | finish no earlier than 2003-11-21 | G2 | 848h | 848h |  |  | Rel-6 |  |  |  |  |  |
| 285 | 40.5 | **MS conformance testing** | 31d? | 2003-12-19 A | 2004-01-30 A | 100% |  | 2003-12-19 | 2004-01-30 | 31d? |  |  | G3 | 248h | 248h |  |  | Rel-6 |  |  |  |  |  |
| 286 | 36.4.1 | MS conformance tests | 31d? | 2003-12-19 A | 2004-01-30 A | 100% |  | 2003-12-19 | 2004-01-30 | 31d? |  | finish no earlier than 2004-01-30 | G4,G5 | 248h | 248h |  |  | Rel-6 |  |  |  |  |  |
| 287 | 36.5 | GERAN A/Gb mode security enhancements | 261d? | 2002-09-26 A | 2003-09-25 | 10% | 234.9d? | 2002-09-26 | 2003-09-25 | 261d? | 579d | finish no earlier than 2003-09-25 | S3 | 2088h | 208.8h |  | Peter Howard, Vodafone | Rel-6 |  |  | 33.102 | peter.howard@vodafone.com |  |
| 288 | 41 | Performance characterisation of default codecs for PS conversational multimedia application | 455d | 2002-09-13 A | 2004-06-10 A | 100% |  | 2002-09-13 | 2004-06-10 | 455d |  | finish no earlier than 2004-06-10 | S4 | 3640h | 3640h | CODCAR | Pasi Ojala (Nokia) | Rel-6 | TSG | Paolo | TR 26.935 | pasi.s.ojala@nokia.com |  |
| 289 | 43 | Study on Privacy Capability | 83d | 2003-11-10 A | 2004-03-03 | 85% | 12.45d | 2003-11-10 | 2004-03-03 | 83d | 465d | start no earlier than 2003-11-10 | S1 | 664h | 564.4h | PrivCap | Liz Daniel, Lucent | Rel-6 | TSG | Michael | TR 21.xyz |  |  |
| 290 | 44 | **OAM&P** | 591d? | 2002-09-12 A | 2004-12-16 | 81% | 113.96d? | 2002-09-12 | 2004-12-08 | 585d? | 259d |  | S5 | 28957.6h | 20540.9h | OAM | Michael TRUSS (Motorola) | Rel-6 | TSG | Adrian | 32-series | Michael.Truss@MOTOROLA.COM |  |
| 291 | 44.1 | Principles, high level Requirements and Architecture | 526d | 2002-09-12 A | 2004-09-16 A | 100% |  | 2002-09-12 | 2004-09-16 | 526d |  | finish no earlier than 2004-09-16 | S5 | 4208h | 4208h | OAM-AR | Michael TRUSS (Motorola) | Rel-6 | TSG |  | 32.101, 32.102 | Michael.Truss@MOTOROLA.COM | BCaM |
| 292 | 44.2 | Performance Management | 526d | 2002-09-12 A | 2004-09-16 | 80% | 105.2d | 2002-09-12 | 2004-09-16 | 526d | 324d | finish no earlier than 2004-09-16 | S5 | 4208h | 3366.4h | OAM-PM | Christian TOCHE (Nortel Networks) | Rel-6 | TSG |  | 32.41x, 52.402 | toche@NORTELNETWORKS.COM | BCaM |
| 293 | 44.4 | Network Infrastructure Management | 526d | 2002-09-12 A | 2004-09-16 | 85% | 78.9d | 2002-09-12 | 2004-09-16 | 526d | 324d | finish no earlier than 2004-09-16 | S5 | 4208h | 3576.8h | OAM-NIM | Thomas TOVINGER (Ericsson) | Rel-6 | TSG |  | 32.15x, 32.3/6/7xy | Thomas.Tovinger@emw.ericsson.se |  |
| 294 | 44.5 | **Trace Management** | 585d? | 2002-09-20 A | 2004-12-16 | 69% | 178.76d? | 2002-09-20 | 2004-12-08 | 579d? | 259d |  | S5 | 11728h | 6317.28h | OAM-Trace | Kari RÖNKÄ (Nokia) | Rel-6 | TSG |  | 32.42x, 52.008 | kari.t.ronka@nokia.com |  |
| 295 | 39.4.1 | Subscriber and UE trace management | 585d | 2002-09-20 A | 2004-12-16 | 80% | 117d | 2002-09-20 | 2004-09-16 | 520d | 259d | finish no earlier than 2004-12-16 | S5 | 4680h | 3744h | OAM-Trace | Kari RÖNKÄ (Nokia) | Rel-6 | TSG |  | 32.42x, 52.008 | kari.t.ronka@nokia.com |  |
| 296 | 39.4.2 | Subscriber and equipment trace in UTRAN | 268d? | 2003-06-06 A | 2004-06-15 A | 100% |  | 2003-06-06 | 2004-06-15 | 268d? |  | finish no earlier than 2004-06-15 | R3 | 2144h | 2144h | OAM-Trace-RAN | Yann Sehedi, Nortel | Rel-6 | TSG | MCC_RAN | TS25.413, 25.420, 25.423 | sehedic@nortelnetworks.com |  |
| 297 | 39.4.3 | SIP enhancements for trace | 213d? | 2004-02-16 A | 2004-12-08 | 2% | 208.74d? | 2004-02-16 | 2004-12-08 | 213d? | 265d | finish no earlier than 2004-12-08 | N1 | 1704h | 34.08h |  |  | Rel-6 |  |  |  |  |  |

Notes:
- 274: Started
- 276: Started
- 280: Completed at GERAN#17
- 285: Closed, no work needed
- 286: Closed, no work needed
- 287: Possible changes to 33.102 or new specification needed.
- 290: SA#24: Completionl delayed 09/04->12/04 due to OAM-Trace.
- 291: SA#24: Completed
- 294: SA#24: RAN3 completed. For the rest Completion delayed 09/04->12/04 due to OAM-Trace & CN1 input.
- 295: SA#24: Completionl delayed 09/04->12/04 due to OAM-Trace.

| ID | WBS | Task | Duration | Start | Finish | Complete | Remaining | Baseline start | Baseline finish | Baseline duration | Total slack | Constraint | Resources | Work | Actual work | Text1 | Text3 | Text4 | Text5 | Text6 | Text7 | Text8 | Text2 | Text9 |
| --- | --- | --- | --- | --- | --- | --- | --- | --- | --- | --- | --- | --- | --- | --- | --- | --- | --- | --- | --- | --- | --- | --- | --- | --- |
| 298 | 40 | **Charging Management** | 476d? | 2002-11-21 A | 2004-09-16 | 85% | 72.24d? | 2002-11-21 | 2004-09-16 | 476d? | 324d |  | S5 | 20416h | 14678.5h | CH | 32.2xy | Karl-Heinz NENNER (T-Mobile) | karl-heinz.nenner@t-mobile.de | Rel-6 | TSG | Adrian |  |  |
| 299 | 40.1 | Charging Management for Bearer level | 390d? | 2003-03-21 A | 2004-09-16 | 85% | 58.5d? | 2003-03-21 | 2004-09-16 | 390d? | 324d | finish no earlier than 2004-09-16 | S5 | 3120h | 2652h | CH-BC |  | Benni ALEXANDER (Nokia) |  | Rel-6 | TSG |  |  |  |
| 300 | 40.2 | Charging Management for the IMS | 390d? | 2003-03-21 A | 2004-09-16 | 85% | 58.5d? | 2003-03-21 | 2004-09-16 | 390d? | 324d | finish no earlier than 2004-09-16 | S5 | 3120h | 2652h | CH-IC |  | Patrik TEPPO (Ericsson) |  | Rel-6 | TSG |  |  |  |
| 301 | 40.3 | Charging Management for the Service domain | 390d? | 2003-03-21 A | 2004-09-16 | 85% | 58.5d? | 2003-03-21 | 2004-09-16 | 390d? | 324d | finish no earlier than 2004-09-16 | S5 | 3120h | 2652h | CH-SC |  | Gerald GÖRMER (Siemens) |  | Rel-6 | TSG |  |  |  |
| 302 | 40.4 | **Overall architectural aspects of IP flow based bearer level charging** | 442d? | 2002-11-21 A | 2004-07-30 | 84% | 69.06d? | 2002-11-21 | 2004-07-30 | 442d? | 358d |  | S2 | 7248h | 5109.28h | CH-FBC | 23.125 |  |  | Rel-6 |  |  |  |  |
| 303 | 40.4.1 | Overall definition of FBC architecture | 334d? | 2002-11-21 A | 2004-03-02 | 99% | 1d? | 2002-11-21 | 2004-03-02 | 334d? | 466d | start no earlier than 2002-11-21 | S2 | 2672h | 2664h |  |  |  |  | Rel-6 |  |  |  |  |
| 304 | 40.4.2 | Study on providing policy control with FBC | 130d? | 2004-02-02 A | 2004-07-30 | 45% | 71.5d? | 2004-02-02 | 2004-07-30 | 130d? | 358d | start no earlier than 2004-02-01 | S2 | 1040h | 468h |  |  |  |  | Rel-6 |  |  |  |  |
| 305 | 13 | **Rel-6 UICC/USIM enhancements and interworking** | 889d | 2000-09-25 A | 2004-02-19 | 99% | 8.4d | 2000-09-25 | 2004-02-19 | 889d | 474d |  | T3 | 26760h | 23288.6h | USAT1 |  |  |  | Rel-6 | TSG | Claus | Ter | 1800 |
| 306 | 13.1 | **UICC API** | 502d | 2002-03-20 A | 2004-02-19 | 98% | 10.73d | 2002-03-20 | 2004-02-19 | 502d | 474d |  | T3 | 8584h | 8400.59h | USAT1-API |  |  |  | Rel-6 |  |  | Ter | 1802 |
| 307 | 13.1.1 | Java API Test specification | 59d | 2002-03-20 A | 2002-06-10 A | 100% |  | 2002-03-20 | 2002-06-10 | 59d |  | finish no earlier than 2002-09-20 | T3 | 472h | 472h |  |  | Mario Pérez (Microelectrónica Española) |  | Rel-6 |  |  |  |  |
| 308 | 13.1.2 | Java API Test specification (TS 43.019 Rel-5) | 268d | 2002-05-30 A | 2003-06-09 A | 100% |  | 2002-05-30 | 2003-06-09 | 268d |  | finish no earlier than 2003-09-17 | T3 | 2144h | 2144h |  |  | Mario Pérez (Microelectrónica Española) |  | Rel-6 |  |  |  |  |
| 309 | 41.1.3 | 2G/3G Java Card™ API based applet interworking | 244d | 2003-03-17 A | 2004-02-19 | 95% | 12.2d | 2003-03-17 | 2004-02-19 | 244d | 474d | finish no earlier than 2004-02-19 | T3 | 1952h | 1854.4h | USAT1-API |  | Stéphane Andrau-Oberthur Card Systems |  | Rel-6 | TSG | Claus |  |  |
| 310 | 41.2 | **Rel-6 USIM toolkit enhancements** | 525d | 2000-09-25 A | 2002-09-27 | 99% | 0d | 2000-09-25 | 2002-09-27 | 525d | 0d |  | T3 | 14160h | 10910h |  |  |  |  | Rel-6 |  | Claus |  |  |
| 311 | 41.2.1 | **C SIM API** | 525d | 2000-09-25 A | 2002-09-27 A | 100% |  | 2000-09-25 | 2002-09-27 | 525d |  |  | T3 | 9960h | 9960h | USAT1-API-MULTOS |  |  |  | Rel-6 | TSG |  | Ter | 2031 |
| 312 | 41.2.1.1 | Specification | 525d | 2000-09-25 A | 2002-09-27 A | 100% |  | 2000-09-25 | 2002-09-27 | 525d |  | finish no earlier than 2002-09-27 | T3 | 4200h | 4200h |  |  | Neil Livingston – Aspects Software |  | Rel-6 | TSG |  | Ter | 2032 |
| 313 | 41.2.1.2 | Test specification | 195d | 2001-01-01 A | 2001-09-28 A | 100% |  | 2001-01-01 | 2001-09-28 | 195d |  | finish no earlier than 2001-09-28 | T3 | 1560h | 1560h |  |  | Neil Livingston – Aspects Software |  | Rel-6 | TSG |  | Ter | 2033 |
| 314 | 42 | **Packet Switched Streaming Services Rel-6** | 479d? | 2002-11-18 A | 2004-09-16 | 92% | 40.36d? | 2002-11-18 | 2004-09-16 | 479d? | 324d |  | S4 | 8200h | 7509.16h | PSSrel6 |  | Olle Franceschi (Ericsson) | olle.franceschi@ericsson.com | Rel-6 | TSG | Paolo |  |  |
| 315 | 42.1 | Stage 1 | 86d? | 2002-11-18 A | 2003-03-17 A | 100% |  | 2002-11-18 | 2003-03-17 | 86d? |  | finish no earlier than 2003-03-17 | S1 | 688h | 688h |  | 22.233 |  |  | Rel-6 | TSG |  |  |  |
| 316 | 42.2 | Stage 3 | 460d? | 2002-12-13 A | 2004-09-16 | 90% | 46d? | 2002-12-13 | 2004-09-16 | 460d? | 324d | finish no earlier than 2004-09-16 | S4 | 3680h | 3312h | PSSrel6-Stage3 | 26.233, 26.234, 26.244, 26.245, 26.246 | Olle Franceschi (Ericsson) | olle.franceschi@ericsson.com | Rel-6 | WG | Paolo |  |  |
| 317 | 43 | AMR-WB extension for high audio quality | 390d | 2002-12-13 A | 2004-06-10 | 95% | 19.5d | 2002-12-13 | 2004-06-10 | 390d | 394d | finish no earlier than 2004-06-10 | S4 | 3120h | 2964h | AMRWB+ |  | Janne Vainio (Nokia) | janne.m.vainio@nokia.com | Rel-6 | TSG | Paolo |  |  |
| 318 | 44 | Codec Enhancements for Packet Switched Conversational Multimedia Applications | 133d? | 2004-03-16 A | 2004-09-16 | 20% | 106.4d? | 2004-03-16 | 2004-09-16 | 133d? | 324d | finish no earlier than 2004-09-16 | S4 | 1064h | 212.8h | CEPSCM | 26.235, 26.236 | Miska Hannuksela (Nokia) | miska.hannuksela@nokia.com | Rel-6 | WG | Paolo |  |  |
| 319 | 45 | 3G-324M Improvements | 133d? | 2004-03-16 A | 2004-09-16 | 40% | 79.8d? | 2004-03-16 | 2004-09-16 | 133d? | 324d | finish no earlier than 2004-09-16 | S4 | 1064h | 425.6h | 3G-324MI | 26.111, 26.911 | Bo Burman, Ericsson | bo.burman@ericsson.com | Rel-6 | WG | Paolo |  |  |
| 320 | 46 | Single Antenna Receiver Interference Cancellation (SAIC) | 420.92d? | 2002-11-15 A | 2004-08-27 | 90% | 42.09d? | 2002-11-15 | 2004-06-25 | 375.92d? | 338d | finish no earlier than 2004-08-27 | GP; G1 | 6734.72h | 6061.25h | SAIC |  | Marc Grant, Cingular Wireless |  | Rel-6 | TSG |  |  |  |
| 321 | 47 | **Support of Conversational Services in A/Gb mode via the PS domain** | 406d? | 2003-02-07 A | 2004-08-27 | 28% | 292.78d? | 2003-02-07 | 2004-08-27 | 406d? | 338d |  | GP | 13512h | 2258.93h | SCSAGB |  | David Bladsjö, Ericsson | david.bladsjo@ericsson.com | Rel-6 | TSG |  |  |  |
| 322 | 47.1 | Creation of a TR | 206d? | 2003-02-07 A | 2003-11-21 A | 100% |  | 2003-02-07 | 2003-11-21 | 206d? |  | finish no earlier than 2003-11-21 | GP | 1648h | 1648h | SCSAGB-TR |  | David Bladsjö, Ericsson |  | Rel-6 | TSG |  |  |  |
| 323 | 47.2 | Stage 2 | 201d? | 2003-11-21 A | 2004-08-27 | 35% | 130.65d? | 2003-11-21 | 2004-08-27 | 201d? | 338d | finish no earlier than 2004-08-27 | GP | 1608h | 562.8h | SCSAGB-Stage2 |  | David Bladsjö, Ericsson |  | Rel-6 | TSG |  |  |  |
| 324 | 47.3 | Radio Channel Support | 146d? | 2004-02-06 | 2004-08-27 |  |  | 2004-02-06 | 2004-08-27 | 146d? | 338d | finish no earlier than 2004-08-27 | GP | 1168h |  | SCSAGB-RCS |  | David Bladsjö, Ericsson |  | Rel-6 | TSG |  |  |  |
| 325 | 47.4 | Definition of radio resource management functionality | 146d? | 2004-02-06 | 2004-08-27 |  |  | 2004-02-06 | 2004-08-27 | 146d? | 338d | finish no earlier than 2004-08-27 | GP; G2 | 2336h |  | SCSAGB-RRM |  | David Bladsjö, Ericsson |  | Rel-6 | TSG |  |  |  |
| 326 | 47.5 | PS Handover | 146d? | 2004-02-06 | 2004-08-27 |  |  | 2004-02-06 | 2004-08-27 | 146d? | 338d | finish no earlier than 2004-08-27 | GP | 1168h |  | SCSAGB-PSH |  | David Bladsjö, Ericsson |  | Rel-6 | TSG |  |  |  |
| 327 | 47.6 | Modifications to FLO | 146d? | 2004-02-06 | 2004-08-27 |  |  | 2004-02-06 | 2004-08-27 | 146d? | 338d | finish no earlier than 2004-08-27 | GP; G2 | 2336h |  | SCSAGB-FLO |  | David Bladsjö, Ericsson |  | Rel-6 | TSG |  |  |  |

Notes:
- 298: az: SA#23 TSG approval 06/04->09/04
- 306: 8/3/2001: test spec is based on R99 core spec, so deleted from Workplan
- 315: 2nd resp SA4
- 323: Started
- 324: Not started
- 325: Not started
- 326: Not started
- 327: Not started

| ID | WBS | Task | Duration | Start | Finish | Complete | Remaining | Baseline start | Baseline finish | Baseline duration | Total slack | Constraint | Resources | Work | Actual work | Text1 | Text4 | Text6 | Text7 | Text8 | Text3 | Text5 |
| --- | --- | --- | --- | --- | --- | --- | --- | --- | --- | --- | --- | --- | --- | --- | --- | --- | --- | --- | --- | --- | --- | --- |
| 328 | 48 | **Enhancement of dialled service for CAMEL** | 199d | 2003-03-28 A | 2003-12-31 A | 100% |  | 2003-03-28 | 2003-12-31 | 199d |  |  | S1 | 3184h | 3184h | EDCAMEL | Craig Bishop, Samsung Electronics Research Institute | Rel-6 | TSG | Andrijana |  |  |
| 329 | 48.1 | Stages 2 and 3 | 199d | 2003-03-28 A | 2003-12-31 A | 100% |  | 2003-03-28 | 2003-12-31 | 199d |  | finish no earlier than 2003-09-19 | N4 | 1592h | 1592h |  |  | Rel-6 |  |  |  |  |
| 330 | 49 | Bandwidth and resource savings in CS networks | 273d? | 2003-06-01 A | 2004-06-16 A | 100% |  | 2003-06-01 | 2004-06-16 | 273d? |  | finish no earlier than 2004-06-16 | S2 | 2184h | 2184h | BARS |  | Rel-6 |  |  | 23.977 |  |
| 331 | 50 | FS on (U)SIM Security Reuse by Peripheral Devices on Local Interfaces | 127d? | 2003-07-03 A | 2003-12-26 | 5% | 120.65d? | 2003-07-03 | 2003-12-26 | 127d? | 513d | finish no earlier than 2003-12-26 | S3 | 1016h | 50.8h |  | Raziq Yaqub, Toshiba America Research Inc. | Rel-6 | TSG | Maurice |  | ryaqub@tari.toshiba.com |
| 332 | 51 | **Multiple TBF in A/Gb mode** | 581d? | 2002-04-05 A | 2004-06-25 | 65% | 201.05d? | 2002-04-05 | 2004-06-25 | 581d? | 383d |  | GP; G2 | 37368h | 27408.6h | MULTBF | Gunnar Mildh, Ericsson | Rel-6 | TSG | Paolo |  |  |
| 333 | 51.1 | **Multiple TBF in A/Gb mode** | 366d? | 2002-04-05 A | 2003-08-29 A | 100% |  | 2002-04-05 | 2003-08-29 | 366d? |  |  | GP; G2 | 23424h | 23424h | MULTBF-Agbmode | Gunnar Mildh, Ericsson | Rel-6 | TSG |  |  |  |
| 334 | 51.1.1 | Multiple TBF Concept paper | 366d? | 2002-04-05 A | 2003-08-29 A | 100% |  | 2002-04-05 | 2003-08-29 | 366d? |  | finish no earlier than 2003-08-29 | GP; G2 | 5856h | 5856h |  |  | Rel-6 |  |  |  |  |
| 335 | 51.1.2 | Multiple TBF Stage 2 (43.064) CRs | 366d? | 2002-04-05 A | 2003-08-29 A | 100% |  | 2002-04-05 | 2003-08-29 | 366d? |  | finish no earlier than 2003-08-29 | GP; G2 | 5856h | 5856h |  |  | Rel-6 |  |  |  |  |
| 336 | 51.1.3 | Multiple TBF Stage 3 (44.060) CRs | 366d? | 2002-04-05 A | 2003-08-29 A | 100% |  | 2002-04-05 | 2003-08-29 | 366d? |  | finish no earlier than 2003-08-29 | GP; G2 | 5856h | 5856h |  |  | Rel-6 |  |  |  |  |
| 337 | 51.2 | Multiple TBF in A/Gb mode – MS testing | 581d? | 2002-04-05 | 2004-06-25 |  |  | 2002-04-05 | 2004-06-25 | 581d? | 383d | finish no earlier than 2004-06-25 | G3 | 4648h |  | MULTBF-Testing | Gunnar Mildh, Ericsson | Rel-6 | TSG | Paolo |  |  |
| 338 | 52 | **Alignment between the test-regimes for GERAN capable MS** | 261d? | 2003-08-29 A | 2004-08-27 | 80% | 52.2d? | 2003-08-29 | 2004-08-27 | 261d? | 338d |  | G3 | 4176h | 1670.4h | ALTERE | Toubassi, Ericsson | Rel-6 | TSG | Michael |  |  |
| 339 | 52.1 | Determine the controversial test cases in the different test regimes and align them with 3GPP GERAN test specifications. Such test cases to be added to TS 51.010. | 261d? | 2003-08-29 A | 2004-08-27 | 80% | 52.2d? | 2003-08-29 | 2004-08-27 | 261d? | 338d | finish no earlier than 2004-08-27 | G3 | 2088h | 1670.4h | ALTERE-TC |  | Rel-6 | TSG |  |  |  |
| 340 | 53 | Addition of U-TDOA in the CS domain | 111d? | 2003-11-21 A | 2004-04-23 A | 100% |  | 2003-11-21 | 2004-04-23 | 111d? |  | finish no earlier than 2004-04-23 | GP | 888h | 888h | UTDOACS | Bob Gross, Rhys Robinson, TruePosition, Inc. | Rel-6 | TSG | Paolo |  | rlgross@trueposition.com |
| 341 | 54 | Addition of U-TDOA in the PS domain | 361d? | 2003-06-27 A | 2004-11-12 | 5% | 342.95d? | 2003-06-27 | 2004-11-12 | 361d? | 283d | finish no earlier than 2004-11-12 | GP | 2888h | 144.4h | UTDOAPS | Bob Gross, Rhys Robinson, TruePosition, Inc. | Rel-6 | TSG | Paolo |  | rlgross@trueposition.com |
| 342 | 55 | **Downlink Advanced Receiver Performance** | 332d? | 2003-11-21 A | 2005-02-28 | 27% | 243.94d? | 2003-11-21 | 2005-02-28 | 332d? | 207d |  | GP | 16576h | 2872.53h | DARP | Tommy Bysted, Nokia | Rel-6 | TSG | Paolo |  | tommy.bysted@nokia.com |
| 343 | 55.1 | DARP test scenarios | 201d? | 2003-11-21 A | 2004-08-27 | 45% | 110.55d? | 2003-11-21 | 2004-08-27 | 201d? | 338d | finish no earlier than 2004-08-27 | GP | 1608h | 723.6h | DARP-TS | Tommy Bysted, Nokia | Rel-6 | TSG | Paolo |  | tommy.bysted@nokia.com |
| 344 | 55.2 | **DARP for GMSK modulated voice services** | 201d? | 2004-02-06 A | 2004-11-12 | 15% | 170.85d? | 2004-02-06 | 2004-11-12 | 201d? | 283d |  | GP | 4824h | 482.4h | DARP-GMSK | Tommy Bysted, Nokia | Rel-6 | TSG | Paolo |  | tommy.bysted@nokia.com |
| 345 | 55.2.1 | Performance requirements in 45.005 | 201d? | 2004-02-06 A | 2004-11-12 | 15% | 170.85d? | 2004-02-06 | 2004-11-12 | 201d? | 283d | finish no earlier than 2004-11-12 | GP | 1608h | 241.2h | DARP-GMSK-Perf |  | Rel-6 | TSG |  |  |  |
| 346 | 55.2.2 | Radio subsystem link control in 45.008 | 201d? | 2004-02-06 A | 2004-11-12 | 15% | 170.85d? | 2004-02-06 | 2004-11-12 | 201d? | 283d | finish no earlier than 2004-11-12 | GP | 1608h | 241.2h | DARP-GMSK-LC |  | Rel-6 | TSG |  |  |  |
| 347 | 55.3 | **DARP for GPRS and EGPRS MCS1-MCS4** | 201d? | 2004-02-06 A | 2004-11-12 | 10% | 180.9d? | 2004-02-06 | 2004-11-12 | 201d? | 283d |  | GP | 4824h | 321.6h | DARP-GPRSE | Tommy Bysted, Nokia | Rel-6 | TSG | Paolo |  | tommy.bysted@nokia.com |
| 348 | 55.3.1 | Performance requirements in 45.005 | 201d? | 2004-02-06 A | 2004-11-12 | 10% | 180.9d? | 2004-02-06 | 2004-11-12 | 201d? | 283d | finish no earlier than 2004-11-12 | GP | 1608h | 160.8h | DARP-GPRSE-Perf |  | Rel-6 | TSG |  |  |  |
| 349 | 55.3.2 | Radio subsystem link control in 45.008 | 201d? | 2004-02-06 A | 2004-11-12 | 10% | 180.9d? | 2004-02-06 | 2004-11-12 | 201d? | 283d | finish no earlier than 2004-11-12 | GP | 1608h | 160.8h | DARP-GPRSE-LC |  | Rel-6 | TSG |  |  |  |
| 350 | 55.4 | DARP Capability signalling | 201d? | 2003-11-21 A | 2004-08-27 | 75% | 50.25d? | 2003-11-21 | 2004-06-25 | 156d? | 338d | finish no earlier than 2004-08-27 | GP | 1608h | 1206h | DARP-CAPSIG | Tommy Bysted, Nokia | Rel-6 | TSG | Paolo |  | tommy.bysted@nokia.com |
| 351 | 55.5 | GERAN MS Conformance test for DARP | 132d? | 2004-08-27 A | 2005-02-28 | 10% | 118.8d? | 2004-08-27 | 2005-02-28 | 132d? | 207d | finish no earlier than 2005-02-28 | G3 | 1056h | 105.6h | ARP-ConfTest | Tommy Bysted, Nokia | Rel-6 | TSG | Michael |  | tommy.bysted@nokia.com |

Notes:
- 331: Approved TSG#20
- 336: Not started
- 337: Not started
- 339: Started
- 340: Completed, except for potential LMU performance specs
- 341: Started
- 343: Started
- 344: Started
- 345: Started
- 346: Started
- 347: Started
- 348: Started
- 349: Started
- 350: Started
- 351: Started

| ID | WBS | Task | Duration | Start | Finish | Complete | Remaining | Baseline start | Baseline finish | Baseline duration | Total slack | Constraint | Resources | Work | Actual work | Text1 | Text4 | Text5 | Text6 | Text7 | Text8 | Text3 |
| --- | --- | --- | --- | --- | --- | --- | --- | --- | --- | --- | --- | --- | --- | --- | --- | --- | --- | --- | --- | --- | --- | --- |
| 352 | 56 | **Reduction of PS service interruption in Dual Transfer Mode** | 256d? | 2003-11-21 A | 2004-11-12 | 50% | 128.82d? | 2003-11-21 | 2004-11-12 | 256d? | 283d |  | G2 | 5808h | 1892.18h | PSintDTM | Toby Proctor, Siemens | toby.proctor@roke.co.uk | Rel-6 | TSG | Gert |  |
| 353 | 56.1 | Use case and requirement definition | 111d? | 2003-11-21 A | 2004-04-23 A | 100% |  | 2003-11-21 | 2004-04-23 | 111d? |  | finish no earlier than 2004-04-23 | G2 | 888h | 888h | PSintDTM-Req | Toby Proctor, Siemens | toby.proctor@roke.co.uk | Rel-6 | TSG | Gert |  |
| 354 | 56.2 | Performance Study of Current Procedures | 111d? | 2003-11-21 A | 2004-04-23 A | 100% |  | 2003-11-21 | 2004-04-23 | 111d? |  | start no earlier than 2003-11-21 | G2 | 888h | 888h | PSintDTM-Perf | Toby Proctor, Siemens | toby.proctor@roke.co.uk | Rel-6 | TSG | Gert |  |
| 355 | 56.3 | Reduction of service interruption times and packet loss during Dual Transfer Mode and mobility procedures | 46d? | 2004-04-23 A | 2004-06-25 | 25% | 34.5d? | 2004-04-23 | 2004-06-25 | 46d? | 383d | finish no earlier than 2004-06-25 | G2 | 368h | 92h | PSintDTM-Reduct | Toby Proctor, Siemens | toby.proctor@roke.co.uk | Rel-6 | TSG | Gert |  |
| 356 | 56.4 | MS Conformance testing | 101d? | 2004-06-25 | 2004-11-12 |  |  | 2004-06-25 | 2004-11-12 | 101d? | 283d | finish no earlier than 2004-11-12 | G3 | 808h |  | PSintDTM-ConfMS |  |  | Rel-6 | TSG | Michael |  |
| 357 | 56.5 | BTS Conformance testing | 101d? | 2004-06-25 | 2004-11-12 |  |  | 2004-06-25 | 2004-11-12 | 101d? | 283d | finish no earlier than 2004-11-12 | G3 | 808h |  | PSintDTM-ConfBTS |  |  | Rel-6 | TSG | Michael |  |
| 358 | 57 | CAMEL prepay interworking with SCUDIF | 206d | 2003-12-08 A | 2004-10-05 |  | 206d | 2003-12-08 | 2004-10-05 | 206d | 311.7d |  | N4 | 1648h |  | SCCAMEL |  |  | Rel-6 |  |  |  |
| 359 | 58 | **Circuit Switched Video and Voice Service Improvements** | 210d? | 2004-01-12 A | 2004-10-29 | 47% | 110.69d? | 2004-01-12 | 2004-10-29 | 210d? | 293d |  | S1 | 6896h | 2982h | CS_VSS | John Watson, Vodafone Group |  | Rel-6 | TSG | Michael | 23.801 |
| 360 | 58.1 | Stage 1 - Requirements | 199d | 2004-01-12 A | 2004-10-14 A | 100% |  | 2004-01-12 | 2004-10-14 | 199d |  | finish no earlier than 2004-10-14 | S1 | 1592h | 1592h |  | John Watson, Vodafone Group |  | Rel-6 | TSG | Michael |  |
| 361 | 58.2 | Stage 2 Study on architecture alternatives | 155d? | 2004-01-12 A | 2004-08-13 | 80% | 31d? | 2004-01-12 | 2004-08-13 | 155d? | 348d | finish no earlier than 2004-08-13 | S2 | 1240h | 992h |  |  |  |  |  |  |  |
| 362 | 58.3 | Stage 2 description on Redial | 130d? | 2004-05-03 | 2004-10-29 |  |  | 2004-05-03 | 2004-10-29 | 130d? | 293d | start no earlier than 2004-05-01 | S2 | 1040h |  |  |  |  |  |  |  | 23.903 |
| 363 | 58.4 | GERAN2 Part | 199d | 2004-01-12 | 2004-10-14 |  |  | 2004-01-12 | 2004-10-14 | 199d | 304d | start no earlier than 2004-01-12 | G2 | 1592h |  |  |  |  | Rel-6 | TSG | Gert |  |
| 364 | 59 | **Access Class Barring and Overload Protection** | 187d? | 2004-03-15 A | 2004-11-30 | 20% | 149.15d? | 2004-03-15 | 2004-11-30 | 187d? | 271d |  | S2 | 4600h | 931.14h | ACBOP | Chris Pudney, Vodafone |  |  | TSG | Sang-Ui | 23.898 |
| 365 | 59.1 | TR on Stage 2 | 187d? | 2004-03-15 A | 2004-11-30 | 42% | 108.46d? | 2004-03-15 | 2004-11-30 | 187d? | 271d | finish no earlier than 2004-11-30 | S2 | 1496h | 628.32h |  |  |  |  | TSG |  |  |
| 366 | 59.2 | Extra ACBOP information in RAN | 67d? | 2004-03-15 | 2004-06-15 |  |  | 2004-03-15 | 2004-06-15 | 67d? | 391d | start no earlier than 2004-03-15 | RP | 536h |  |  |  |  |  | TSG |  | 25.331 |
| 367 | 59.3 | Extra ACBOP information in GERAN | 67d? | 2004-03-15 | 2004-06-15 |  |  | 2004-03-15 | 2004-06-15 | 67d? | 391d | start no earlier than 2004-03-15 | GP | 536h |  |  |  |  |  | TSG |  | 44.018 |
| 368 | 59.4 | Potential impact on Iu interface Overload functionality | 67d? | 2004-03-15 | 2004-06-15 |  |  | 2004-03-15 | 2004-06-15 | 67d? | 391d | start no earlier than 2004-03-15 | RP | 536h |  |  |  |  |  | TSG |  | 25.413 |
| 369 | 60 | **Combining CS bearers with IMS** | 187d? | 2004-03-15 | 2004-11-30 |  |  | 2004-03-15 | 2004-11-30 | 187d? | 271d |  | S2 | 2992h |  | CSI | Mark Watson, Nortel Networks |  |  | TSG | Sang-Ui | 23.899 |
| 370 | 60.1 | TR on Alternative Architectures for Combining CS Bearers with IMS | 187d? | 2004-03-15 | 2004-11-30 |  |  | 2004-03-15 | 2004-11-30 | 187d? | 271d | finish no earlier than 2004-11-30 | S2 | 1496h |  |  |  |  |  | TSG |  |  |
| 371 | 61 | USSD message delivery and transfer to USIM | 152d? | 2004-03-18 A | 2004-10-15 | 10% | 136.8d? | 2004-03-18 | 2004-10-15 | 152d? | 303d | start no earlier than 2004-03-18 | S1 | 1216h | 121.6h |  |  |  |  | TSG |  | 22.090 |
| 372 | 62 | Generic Access to A/Gb Interface | 156d? | 2004-06-25 | 2005-01-28 |  |  |  |  |  | 228d | finish no earlier than 2005-01-28 | GP | 1248h |  | GAAG | Motorola |  |  | TSG | Paolo |  |

Notes:
- 353: Started
- 354: Started
- 355: Started
- 356: Not started
- 357: Not started
